# CRONOGRAMA DE OBRA

Schedule from MS Project, 2016-04-01 to 2016-06-29, costs in S/..

## Calendars

- Estándar: Mon-Sun 08:00-12:00, 13:00-17:00.

## Resources

| Resource | Group | Rate | Cost per use |
| --- | --- | --- | --- |
| TOPOGRAFO | Mano de Obra | 19 |  |
| OPERARIO | Mano de Obra | 17.17 |  |
| OFICIAL | Mano de Obra | 14.56 |  |
| PEON | Mano de Obra | 13.11 |  |
| ALAMBRE NEGRO RECOCIDO # 16 | Material |  | 5 |
| ALAMBRE NEGRO RECOCIDO # 8 | Material |  | 5 |
| FIBRA MONOFILAMENTO DE POLIPROPILENO | Material |  | 18.03 |
| CLAVOS PARA MADERA C/C 2 1/2" | Material |  | 4.5 |
| CLAVOS PARA MADERA C/C 3" | Material |  | 4.5 |
| ALAMBRE NEGRO N°16 | Material |  | 5 |
| ALAMBRE NEGRO N°8 | Material |  | 5 |
| PERNO DE 5/8"x20" I/ARANDELA Y TUERCA | Material |  | 15 |
| REJILLA DE FIERRO SUMIDERO (0.6x0.50) C/ MARCO 2"x2"x3/16" Y REJAS DE PLATINA DE 2"x3/16 | Material |  | 550 |
| CLAVOS PARA CALAMINA | Material |  | 12 |
| CLAVOS 3" | Material |  | 4.5 |
| PERNOS GRADO 5 PARA BRIDAS DE HD 3/4"X4"+WACHA DE PRESION | Material |  | 5.58 |
| GANCHOS DE FIERRO | Material |  | 7 |
| GUARDACABO DE FºGºP/ CABLE 3/8" | Material |  | 2 |
| CINTILLOS 3/16" X 6" | Material |  | 0.35 |
| ACERO DE REFUERZO Fy=4200Kg/cm2 GRADO 60 | Material |  | 3.5 |
| ACERO DE CONSTRUCCION LISO Fy=2500 Kg/cm2 GRADO 36 | Material |  | 4 |
| ARENA FINA DE RIO | Material |  | 40 |
| ARENA FINA | Material |  | 40 |
| TIERRA DE CHACRA O VEGETAL | Material |  | 35 |
| ARENA FINA DE RIO | Material |  | 40 |
| TIERRA ROJA (ARCILLA - LIMOS DE BAJA PLASTICIDAD) | Material |  | 30 |
| GRAS | Material |  | 8 |
| PLANTONES | Material |  | 40 |
| ARENA | Material |  | 40 |
| PIEDRA MEDIANA | Material |  | 130 |
| MATERIAL DE PRESTAMO (ARCILLA - LIMOS DE BAJA PLASTICIDAD) | Material |  | 30 |
| MATERIAL DE PRESTAMO SELECCIONADO | Material |  | 20 |
| GRAVA 3/4" - 1" | Material |  | 120 |
| CONDUCTOR DESNUDO de 1x16 MM2 | Material |  | 7.5 |
| CONECTORES A CAJA PVC SEL DE 1" | Material |  | 0.88 |
| CONECTORES DE COBRE | Material |  | 2.2 |
| CONDUCTOR ELECTRICO DE TELEFONO | Material |  | 350 |
| CONDUCTOR ELECTRICO 2 - 1x6 MM2 NYY | Material |  | 16.5 |
| CONDUCTOR ELECTRICO NILT 2X14 MM2 | Material |  | 4.95 |
| CONDUCTOR ELECTRICO THW 1x16 MM2 | Material |  | 8.5 |
| CONDUCTOR ELECTRICO 2-1x 16 MM2 NYY | Material |  | 16.5 |
| CONDUCTOR ELECTRICO 2 - 1x10 MM2 NYY | Material |  | 10.5 |
| CONDUCTOR ELECTRICO 2 - 1x4 MM2 NYY | Material |  | 4.8 |
| CONDUCTOR ELECTRICO 2 - 1x25 MM2 NYY | Material |  | 22.6 |
| CONDUCTOR AUTOPORTANTE 2-1x16+P16MM2 | Material |  | 26 |
| CONDUCTOR NYY 4-1x16MM2 | Material |  | 33 |
| CACHIMBA 160 mm X 45 ISO 25 | Material |  | 45 |
| CORPORATION PVC DE 1/2" | Material |  | 15 |
| CAJA MEDIDOR DE AGUA | Material |  | 18 |
| MARCO Y TAPA FIERRO GALVANIZADO AGUA | Material |  | 30 |
| ARMADO DE ACCESORIOS DE ANCLAJE | Material |  | 501.9 |
| LUMINARIA DOBLE MODELO PULSAR DE 100W | Material |  | 950 |
| LUMINARIA DE ALUMBRADO PUBLICO DE 150W. SIMILAR A AMBAR 2 | Material |  | 850 |
| LUMINARIA DOBLE MODELO RUBI DE 150W | Material |  | 1780 |
| SEMAFOROS TRIPLE TIPO LEDs 10 W | Material |  | 2600 |
| CONTROLADOR DE TRES FASES | Material |  | 1925 |
| TABLERO ELECTRICO | Material |  | 495 |
| CAJA PORTA MEDIDOR | Material |  | 110 |
| INTERRUPTOR HORARIO | Material |  | 145 |
| INTERRUPTOR TERMOMAGNETICO DE 2 X 40 AMP 10 KA | Material |  | 45 |
| CONTACTOR DE 20 AMP | Material |  | 143 |
| CORTACIRCUITO PARA POSTE | Material |  | 29.7 |
| ASFALTO RC-250 | Material |  | 16 |
| LADRILLO DE ARCILLA ICARO (18 HUECOS) 0.09x0.12x0.23m | Material |  | 0.7 |
| BLOQUE DE CONCRETO MURO 40 X 40 X 20 CM. | Material |  | 50 |
| MURETE DE CONCRETO SEGUN DISEÑO | Material |  | 130 |
| CEMENTO PORTLAND TIPO I (42.5KG) | Material |  | 23 |
| PANEL DE Co Ao f'c=350 Kg/cm2 TIPO MA-6L (1.52 x 1.52 x 0.14m) | Material |  | 757.94 |
| PANEL DE Co Ao f'c=350 Kg/cm2 TIPO MB-3L (1.52 x 0.76 x 0.14m) | Material |  | 420.14 |
| PANEL DE Co Ao f'c=350 Kg/cm2 TIPO MB-4L (1.52 x 0.76 x 0.14m) | Material |  | 439.99 |
| PANEL DE Co Ao f'c=350 Kg/cm2 TIPO MA-7L (1.52 x 1.52 x 0.14m) | Material |  | 777.79 |
| PANEL DE Co Ao f'c=350 Kg/cm2 TIPO MF-6L (1.52 x 1.86 x 0.14m) | Material |  | 882.43 |
| PANEL DE Co Ao f'c=350 Kg/cm2 TIPO MC-3L (1.52 x 1.10 x 0.14m) | Material |  | 544.6 |
| PANEL DE Co Ao f'c=350 Kg/cm2 TIPO MF-7L (1.52 x 1.86 x 0.14m) | Material |  | 912.2 |
| PANEL DE Co Ao f'c=350 Kg/cm2 TIPO MC-4L (1.52 x 1.10 x 0.14m) | Material |  | 564.46 |
| CAJA CONDOMINIAL PREFABRICADA DE CONCRETO SIMPLE INC/MARCO Y TAPA DE C.A. Di=0.40m | Material |  | 290 |
| CAJA CONDOMINIAL PREFABRICADA DE CONCRETO SIMPLE INC/MARCO Y TAPA DE C.A. Di=0.60m | Material |  | 350 |
| MURALETA AMARILLO 7.5 X 0.22 M | Material |  | 200 |
| SEMIESFERA | Material |  | 22.04 |
| BENTONITA SODICA | Material |  | 2.5 |
| SELLANTE ELASTOMERICO A BASE DE POLIURETANO | Material |  | 30 |
| CORDONES DE BAQUEROD | Material |  | 0.5 |
| YESO EN BOLSAS DE 18 KG. | Material |  | 18 |
| CINTA AISLANTE | Material |  | 3 |
| CINTA SEÑALADORA AMARILLA | Material |  | 0.4 |
| CINTA SEÑALADORA AMARILLA | Material |  | 53.5 |
| CONOS REFLECTANTES | Material |  | 45 |
| CINTA SEÑALADORA ROJA | Material |  | 53.5 |
| CONECTOR DE COBRE AB 5/8" | Material |  | 5.5 |
| CONECTOR TIPO AB Ø 5/8" | Material |  | 5.5 |
| WATER STOP DE 4" | Material |  | 14 |
| SOLDADURA CELLOCORD 1/8" | Material |  | 10 |
| SOLDADURA CELLOCORD | Material |  | 12 |
| SOLDADURA CORTE | Material |  | 20 |
| CAL HIDRATADA DE 30 Kg | Material |  | 25 |
| HEBILLA PARA CINTA BAND - IT | Material |  | 1.8 |
| CINTA BANDIT 3/4" ANCHO | Material |  | 6.8 |
| PEGAMENTO P/TUBO PVC. | Material |  | 70 |
| YESO DE 28 Kg | Material |  | 25 |
| BARRENO | Material |  | 300 |
| FOTOCOPIAS | Material |  | 0.1 |
| VARILLA DE COBRE DE 5/8" x 2.40m. | Material |  | 160 |
| ADITIVO CURADOR DE CONCRETO - CLIMA CÁLID0 | Material |  | 30 |
| LACA DESMOLDEADORA | Material |  | 110 |
| ACCESORIOS DE FIN DE LINEA | Material |  | 35 |
| ACCESORIOS DE ALINEAMIENTO | Material |  | 32 |
| PEGAMENTO PARA PVC | Material |  | 50 |
| ANILLO DE JEBE D=160MM | Material |  | 8.32 |
| ANILLO DE JEBE D=200MM | Material |  | 11.28 |
| ANILLO H°D° LUFLEX ISO 315MM | Material |  | 32.16 |
| LETRERO DE DESVIO DE TRANSITO | Material |  | 20 |
| MEDIDOR DE ENERGIA MONOFASICO | Material |  | 145 |
| MEDIDOR DE ENERGIA TRIFASICO | Material |  | 462 |
| IMPRIMANTE | Material |  | 18 |
| COLA SINTETICA P/CARPINTERIA | Material |  | 40 |
| CORDEL | Material |  | 0.3 |
| CINTA TEFLON | Material |  | 1.5 |
| WINCHA | Material |  | 50 |
| BOTIQUIN IMPLEMENTADO | Material |  | 1000 |
| EXTINTOR DE DIOXIDO DE POLVO QUIMICO SECO 4-4.5 KG | Material |  | 120 |
| TAPA DE CONCRETO ARMADO PARA BUZON | Material |  | 200 |
| TAPA DE CONCRETO ARMADO PARA BUZON | Material |  | 200 |
| CAJA DE REGISTRO DE CONCRETO | Material |  | 50 |
| CAJAS DE REGISTRO DE 0.4x0.4x0.7 prof. | Material |  | 150 |
| CAJA DE REGISTRO NORMALIZADO | Material |  | 50 |
| TRANSPORTE DE MATERIALES EQUIPOS LIVIANO Y HERRAMIENTAS | Material |  | 9.41 |
| TRANSPORTE DE MATERIALES EQUIPOS LIVIANOS Y HERRAMIENTAS (LIMA - PUCALLPA) | Material |  | 287.18 |
| MOVILIZACION Y DESMOVILIZACION EQUIPO PESADO EN CAMA BAJA 30Tn. | Material |  | 600 |
| MOVILIZACION Y DESMOVILIZACION EQUIPO PESADO DE RODAMIENTO PROPIO | Material |  | 1658 |
| BROCHA DE 4" | Material |  | 5 |
| CHARLAS DE CAPACITACION DE PERSONAL EN SEGURIDAD | Material |  | 1000 |
| ELABORACION IMPLEMENTACION Y ADMINISTRACION DEL PLAN DE SEGURIDAD Y SALUD EN EL TRABAJO | Material |  | 2000 |
| HORMIGON (PUESTO EN OBRA) | Material |  | 75 |
| ENERGIA ELECTRICA P/OBRA POR MES | Material |  | 1000 |
| ALQUILER DE LAPTOP | Material |  | 100 |
| ALQUILER DE PROYECTOR MULTIMEDIA | Material |  | 100 |
| LIJA DE FIERRO # 80 | Material |  | 3 |
| HIPOCLORITO DE CALCIO 70% | Material |  | 15 |
| AGUA | Material |  | 5 |
| AGUA PARA CAMPAMENTO | Material |  | 200 |
| HOJA DE SIERRA P/CORTAR FIERRO | Material |  | 5 |
| WAYPE INDUSTRIAL | Material |  | 2 |
| REFRIGERIO | Material |  | 20 |
| AFICHES | Material |  | 1 |
| CARTELES DE PROMOCION DE LA SEGURIDAD | Material |  | 80 |
| CARTEL DE OBRA (5.00x3.00) BANNER INC/ MATERIALES | Material |  | 900 |
| DERECHOS DE DESCONEXION Y CONEXIÓN. | Material |  | 500 |
| DERECHOS DE CORTE BAJA TENSION AV. BELLAVISTA - JR. IPARIA | Material |  | 80 |
| DERECHOS CONEXIÓN BAJA TENSION AV. BELLAVISTA - JR. IPARIA | Material |  | 25 |
| DERECHOS DE CORTE BAJA TENSION JR. ALCIDES CARRION - JR. LOS TULIPANES | Material |  | 80 |
| DERECHOS CONEXIÓN BAJA TENSION JR. ALCIDES CARRION - JR. LOS TULIPANES | Material |  | 25 |
| PAPEL BOND A4 80 GRAMOS | Material |  | 25 |
| CINTA SEÑALIZADORA MECHEROS Y OTROS | Material |  | 50 |
| GRIFO CONTRA INCENDIO T/POSTE 2 BOCAS | Material |  | 1452 |
| INSUMOS POSTE 8/200 | Material |  | 50 |
| INSUMOS POSTE 8/300 | Material |  | 45 |
| EMPALME SUBTERRANEO TIPO PAÑAL | Material |  | 15 |
| MADERA PARA MUEBLES | Material |  | 2.5 |
| MADERA TORNILLO | Material |  | 2.5 |
| ESTACAS | Material |  | 1.5 |
| MADERA PARA ENCOFRADO | Material |  | 1.8 |
| MADERA PARA APUNTALAMIENTO | Material |  | 1.8 |
| REGLA DE MADERA | Material |  | 3 |
| SEÑALIZACIÓN VERTICAL | Material |  | 650 |
| LUCES ESTROBOSCOPICAS | Material |  | 200 |
| SEÑALIZACION INFORMATIVA DE DESVIO | Material |  | 800 |
| LETRINAS DE POZO SECO | Material |  | 800 |
| ESTACA DE MADERA | Material |  | 1.5 |
| LISTONES DE 2"X3" | Material |  | 2.5 |
| MADERA PARA ACOPLE | Material |  | 1.8 |
| ESTACA DE MADERA | Material |  | 1.5 |
| TRIPLAY LUPUNA DE 4'x8'x 10 mm | Material |  | 35 |
| TRIPLAY DE 4'x8'x 4 mm | Material |  | 21 |
| MADERA SHIHUAHUACO 2"x3" P/ENTRAMADO | Material |  | 2 |
| CAJA PREFABRICADA DE CONCRETO | Material |  | 65 |
| MARCO DE FIERRO FUNDIDO DIAMETRO 0.60m | Material |  | 266.4 |
| MARCO Y TAPA FIERRO GALVANIZADO P/DESAGUE | Material |  | 35 |
| TAPA DE FIERRO GALVANIZADO | Material |  | 65 |
| ABRAZADERA DE ALUMINIO | Material |  | 50 |
| KEROSENE INDUSTRIAL | Material |  | 8 |
| THINER | Material |  | 15 |
| GRASA | Material |  | 20 |
| PINTURA ESMALTE PARA TRAFICO | Material |  | 80 |
| PINTURA ESMALTE SINTETICO | Material |  | 55 |
| PINTURA ESMALTE ANTICORROSIVO | Material |  | 45 |
| PINTURA ESMALTE | Material |  | 45 |
| PINTURA PARA TRAFICO AMARILLA | Material |  | 80 |
| PINTURA PARA TRAFICO BLANCA | Material |  | 80 |
| PINTURA PARA TRAFICO NEGRO | Material |  | 80 |
| ARANDELA CUADRADA 4" X 4" X 1/4" | Material |  | 7.5 |
| BRIDA PARA ACLOPAR TUBERIA H° D° 315 MM | Material |  | 380.5 |
| TECKNOPOR DE 1/2" x 4' x 8' | Material |  | 6.5 |
| POSTE DE C.A.C. DE 9/300 | Material |  | 510 |
| POSTE DE C.A.C. DE 8/200 | Material |  | 456 |
| POSTE DE C.A.C. DE 8/300 | Material |  | 484 |
| CANALETA GUARDACABLE 1/16" X 2.40 M. | Material |  | 45 |
| VARILLA DE ANCLAJE FºGº DE 5/8 " x 2.40 | Material |  | 60 |
| POSTES DE Fº Gº DE 6" ø X 6 M | Material |  | 528 |
| POSTE DE Fº Gº DE 4" ø X 5 M | Material |  | 572 |
| ABRAZADERA DE F°G° | Material |  | 65 |
| SOPORTE DE TRES BRAZOS | Material |  | 165 |
| SOPORTE DE SEMAFOROS | Material |  | 250 |
| SOPORTE DE BRAZO DOBLE | Material |  | 176 |
| SOPORTE DE BRAZO SIMPLE 1 1/2"ø | Material |  | 145 |
| UNION DE REPARACION PVC Ø90mm C/Anillo | Material |  | 46.2 |
| UNION DE REPARACION PVC Ø110mm C/Anillo | Material |  | 62.01 |
| UNION DE REPARACION PVC Ø160mm C/Anillo | Material |  | 92.3 |
| LUBRICANTE | Material |  | 26.67 |
| PLANCHA DE COBRE DE 8"X8"X1/4" | Material |  | 35 |
| TERMINALES DE COBRE PARA CONDUCTOR DE 10 MM2 TIPO OJO | Material |  | 4.03 |
| REDUCCION HIERRO DUCTIL Ø200mm x 90mm | Material |  | 260.4 |
| UNION DRESSER DN 315mm | Material |  | 1800 |
| TUBERIA PVC SP NTP 399.002 Ø 2" CLASE 5 | Material |  | 5.67 |
| TUBERIA PVC SP NTP 399.002 Ø 1/2" CLASE 10 | Material |  | 2.78 |
| TUBO PVC SAP 1" | Material |  | 2.9 |
| TUBO PVC SAP 1 1/4" | Material |  | 5 |
| REDUCC PVC UR Ø110mm x 90mm C/Anillo ISO 4422 | Material |  | 31.25 |
| REDUCC PVC UR Ø160mm x 110mm C/Anillo ISO 4422 | Material |  | 68.9 |
| TAPON PVC UR Ø90mm ISO 4422 | Material |  | 43.2 |
| TAPON Ø315mm HD ISO 2531 TIPO LUFLEX | Material |  | 772.18 |
| TAPON PVC UR Ø110mm ISO 4422 | Material |  | 130.4 |
| TAPON PVC UR Ø160mm ISO 4422 | Material |  | 217.6 |
| CURVA PVC P/AGUA NTP399.166 Ø 1/2" x 45º SP CLASE 10 | Material |  | 2.5 |
| CODO Ø 90mm x 90º HD ISO 2531 TIPO LUFLEX | Material |  | 176 |
| CODO Ø 90mm x 45º HD ISO 2531 TIPO LUFLEX | Material |  | 174 |
| CODO Ø 110mm x 45º HD ISO 2531 TIPO LUFLEX | Material |  | 349 |
| CODO Ø 160mm x 45º HD ISO 2531 TIPO LUFLEX | Material |  | 449 |
| CODO Ø 110mm x 22.5º HD ISO 2531 TIPO LUFLEX | Material |  | 348 |
| CRUZ HD Ø200 x 200mm ISO 2531 TIPO LUFLEX | Material |  | 630.9 |
| CRUZ HD Ø200 x 160mm ISO 2531 TIPO LUFLEX | Material |  | 516.24 |
| TUB. PVC SAL P/DESAGUE DE 2" | Material |  | 3 |
| TEE PVC U.F. DE Ø200mm x 250mm | Material |  | 130 |
| TAPON PVC U.F. C-10 Ø250mm | Material |  | 45 |
| TAPON Ø200mm HD ISO 2531 TIPO LUFLEX | Material |  | 380.6 |
| CODO HD BRIDADO Ø355mm x 45º | Material |  | 691.2 |
| CODO PVC DE Ø250mm x 90º C-10 | Material |  | 65 |
| BATERIA COMPLETA PVC Ø 1/2" | Material |  | 45 |
| TEE HD Ø90 x 90mm ISO 2531 TIPO LUFLEX | Material |  | 156.6 |
| TEE HD Ø110 x 110mm ISO 2531 TIPO LUFLEX | Material |  | 180.54 |
| TEE HD Ø160 x 110mm ISO 2531 TIPO LUFLEX | Material |  | 470.22 |
| TEE HD Ø110 x 90mm ISO 2531 TIPO LUFLEX | Material |  | 174.24 |
| TEE HD Ø110 x 63mm ISO 2531 TIPO LUFLEX | Material |  | 154.5 |
| TEE HD Ø160 x 160mm ISO 2531 TIPO LUFLEX | Material |  | 414.62 |
| TEE HD Ø200 x 90mm ISO 2531 TIPO LUFLEX | Material |  | 492.12 |
| TEE HD Ø315 x 160mm ISO 2531 TIPO LUFLEX | Material |  | 1176.6 |
| TRANSICION HD A PVC DE 315 MM | Material |  | 492 |
| TRANSICION PVC U/F Ø90mm | Material |  | 95.5 |
| TRANSICION PVC U/F Ø110mm | Material |  | 115.91 |
| TUBERIA PVC ISO 4435 UF ø=160 mm S-20 | Material |  | 38.46 |
| GEOTEXTIL NO TEJIDO DE 200 gr/m2 | Material |  | 3.6 |
| SUMINISTRO DE CONTENEDOR DE RESIDUOS SOLIDOS DE 800 LITROS DE CAPACIDAD / INC. LOGO | Material |  | 2500 |
| SUMINISTRO DE CONTENEDOR DE RESIDUOS SOLIDOS DE 120 LITROS DE CAPACIDAD / INC. LOGO | Material |  | 450 |
| SUMINISTRO E INSTALACION DE PUNTOS ECOLOGICOS TRIPLLE 53 LITROS INCLUYE LOGO | Material |  | 1200 |
| ANCLAJE POSTERIOR DE CINTA (barra lisa Ø 16mm y barra tipo J Ø 12mm) | Material |  | 5.58 |
| ABRAZADERA TIPO "S" | Material |  | 1.65 |
| TUBERIA FLEXIBLE CRIBADA HDPE D=4" | Material |  | 9.5 |
| UNION CRIBADA HDPE D=4" | Material |  | 9.75 |
| TUBERIA PVC SAP D=2" | Material |  | 8.5 |
| TUBERIA PVC SAP D=40MM | Material |  | 5.6 |
| TUBERIA PVC ISO 4435 UF ø=200 mm S-25 | Material |  | 47.36 |
| CINTA POLIMERICA DE RESISTENCIA 30 KN | Material |  | 2.78 |
| TUBERIA PVC NTP 399.163 DN 200mm SN 4 UR | Material |  | 49.35 |
| TUBERIA PVC UR DN 90mm Serie 13.3 ISO 4422 | Material |  | 10.44 |
| TUBERIA PVC UR DN 100mm Serie 13.3 ISO 4422 | Material |  | 15.48 |
| TUBERIA PVC UR DN 63mm Serie 13.3 ISO 4422 | Material |  | 8.62 |
| TUBERIA PVC UR DN 110mm Serie 10 ISO 4422 | Material |  | 33.68 |
| TUBERIA PVC UR DN 200mm Serie 10 ISO 4422 | Material |  | 112.2 |
| TUBERIA PVC UR DN 160mm Serie 13.3 ISO 4422 | Material |  | 32.1 |
| TUBERIA PVC UR DN 160mm Serie 10 ISO 4422 | Material |  | 71.51 |
| TUBERIA PVC UR DN 250mm Serie 10 ISO 4422 | Material |  | 173.33 |
| TUBERIA PVC SAP DE 40 MM | Material |  | 5.6 |
| TUBERIA DE HD Ø 315mm | Material |  | 450 |
| ABRAZADERA PVC 90 m m x 1/2" | Material |  | 13.8 |
| ABRAZADERA PVC 110 m m x 1/2" | Material |  | 24 |
| ABRAZADERA PVC 160 m m x 1/2" | Material |  | 32.4 |
| TUBO PVC SAP (LUZ) (E/C) 1" X 3 M. | Material |  | 7 |
| CURVA PVC SAP 1" | Material |  | 4 |
| DOSIS DE SALES ELECTROLITICA | Material |  | 95 |
| TUBERIA PVC SEL Ø 1" | Material |  | 5 |
| CURVA PVC SEL 1" | Material |  | 2 |
| VALVULA COMPUERTA DE BRONCE DE 4" | Material |  | 648 |
| VALVULA ANTIRETORNO D=200 MM. | Material |  | 340 |
| VALVULA DE COMPUERTA HD Ø90mm ISO 7259 TIPO LUFLEX | Material |  | 456 |
| VALVULA DE COMPUERTA HD Ø110mm ISO 7259 TIPO LUFLEX | Material |  | 480 |
| VALVULA DE COMPUERTA HD Ø160mm ISO 7259 TIPO LUFLEX | Material |  | 900 |
| PLACA ACRILICA DE IDENTIFICACION Y CARACTERISTICAS DEL TABLERO | Material |  | 15 |
| CALAMINA GALVANIZADA STANDAR (1.83m.x0.83m.x0.26mm) | Material |  | 18 |
| PLACA RECORDATORIA ACRILICA DE 0.40 X 0.60 (I/MURETE) | Material |  | 500 |
| BARANDA METALICA DE TUBO GALVANIZADO SEG.DIS. | Material |  | 200 |
| CORREA DE SEGURIDAD | Equipo | 140 |  |
| MEGATESTER | Equipo | 100 |  |
| MEGOMETRO | Equipo | 15 |  |
| GUANTES DE CUERO AMARILLO 9 1/2" FLEXIBLE | Equipo | 16 |  |
| MIRA TOPOGRAFICA | Equipo | 5 |  |
| MOLDE METALICO ENCOFRADO CIRCULAR | Equipo | 30 |  |
| FORMADOR DE JUNTAS PLATINA - 50 mm prof. e=6 mm | Equipo | 5 |  |
| BALDE DE PRUEBA TAPON ABRAZADERA Y ACC. | Equipo | 5 |  |
| MIRAS Y JALONES | Equipo | 3 |  |
| TEODOLITO | Equipo | 10 |  |
| MIRAS Y JALONES | Equipo | 5 |  |
| MASCARILLA DESECHABLE CONTRA POLVO | Equipo | 2.5 |  |
| LINEA DE VIDA(CABLE DE CUERO 3/8") | Equipo | 200 |  |
| CASCOS TIPO JOCKEY DE PLASTICO | Equipo | 20 |  |
| BOTAS IMPERMEABLES DE JEBE | Equipo | 20 |  |
| LENTES DE POLICARBONATO LUNA CLARA | Equipo | 7 |  |
| ARNES CON UN ANILLO | Equipo | 128 |  |
| MEZCLADORA DE CONCRETO DE 9 -11P3 | Equipo | 20 |  |
| PIZON SALTARIN | Equipo | 15 |  |
| CAMION PLATAFORMA 6x4 300 HP 20 TON. | Equipo | 180 |  |
| CAMION VOLQUETE 10 M3. | Equipo | 225 |  |
| MONTACARGA 94 HP 8 000 KGS | Equipo | 120 |  |
| MOTOBOMBA 5 HP 3" | Equipo | 70 |  |
| EQUIPO T/HYDROJET P/AGUA A PRESION | Equipo | 110 |  |
| MOTOBOMBA 3 HP | Equipo | 15 |  |
| CAMION VOLQUETE 400HP DE 14 M3 | Equipo | 140 |  |
| VOLQUETE DE 14 M3 | Equipo | 140 |  |
| CAMION CISTERNA 4X2 (AGUA) 122HP 1 500 GAL. | Equipo | 125 |  |
| MOTOBOMBA 4" SUCCION Ø8" | Equipo | 10 |  |
| MAQUINA DE SOLDAR 250 AMP TRIFASICA | Equipo | 15 |  |
| MOTOSIERRA | Equipo | 15 |  |
| MOCHILA EXPARCIDORA | Equipo | 3 |  |
| MAQUINA CON BALDE P/EXTRACCION DE LODOS | Equipo | 100 |  |
| SIERRA CIRCULAR ELECTRICA Y MANUAL | Equipo | 10 |  |
| COCINA DE ASFALTO DE 320 GLS. | Equipo | 20 |  |
| COMPRESORA NEUMATICA 76 HP 125-175 PCM | Equipo | 53.12 |  |
| RODILLO LISO VIBR AUTOP 101-135HP 10-12T | Equipo | 150 |  |
| RODILLO PATA CABRA V.AUT100-135HP 11-13T | Equipo | 200 |  |
| COMPACTADOR VIBR. TIPO SALTARIN 4 HP | Equipo | 20 |  |
| COMPACTADORA TIPO SALTARIN | Equipo | 20 |  |
| EXCAVADORA S/ORUG O S/LLANTAS 170-250HP 1.1-2.75 YD3 | Equipo | 280 |  |
| TRACTOR DE ORUGAS DE 190-240 HP | Equipo | 250 |  |
| CARGADOR S/LLANTAS 350HP 2.30 Yd3 | Equipo | 200 |  |
| CARGADOR FRONTAL CAT 930 | Equipo | 200 |  |
| RETROEXCAVADOR S/LLANTAS 110HP - 1.25Yd3 | Equipo | 160 |  |
| MARTILLO NEUMATICO DE 24 Kg. | Equipo | 20 |  |
| VIBRADOR DE CONCRETO 4 HP 1.50" | Equipo | 10 |  |
| VIBRADOR DE CONCRETO 4 HP 2.40" | Equipo | 10 |  |
| REGLA VIBRATORIA 1 HP | Equipo | 20 |  |
| MOTONIVELADORA DE 125 HP | Equipo | 220 |  |
| PLANCHA COMPACTADORA 4HP | Equipo | 15 |  |
| CAMIONETA RURAL 4x4 | Equipo | 40 |  |
| KIT DE IZAJE (2 ganchos + 1 Triangulo de Izaje) | Equipo | 120 |  |
| SONOMETRO | Equipo | 70 |  |
| HIVOL | Equipo | 70 |  |
| TEODOLITO | Equipo | 10 |  |
| NIVEL | Equipo | 10 |  |
| CAMION GRUA (BRAZO ARTICULADO) | Equipo | 400 |  |
| GRUA DE 20 TN. | Equipo | 220 |  |
| TELUROMETRO | Equipo | 15 |  |
| MEGOMETRO | Equipo | 15 |  |
| EQUIPO TOPOGRAFICO | Equipo | 20 |  |
| EQUIPO TOPOGRAFICO ESTACION TOTAL | Equipo | 15 |  |
| NIVEL TOPOGRAFICO | Equipo | 10 |  |
| CORTADORA DE CONCRETO | Equipo | 30 |  |

## Schedule

| ID | WBS | Task | Type | Duration | Start | Finish | Total slack | Constraint | Cost | Text1 | Text8 | Text2 | Text3 | Text4 | Text6 |
| --- | --- | --- | --- | --- | --- | --- | --- | --- | --- | --- | --- | --- | --- | --- | --- |
| 1 | 1 | **CRONOGRAMA DE ACTIVIDADES DEL EXPEDIENTE TECNICO “CAMBIO DE COLECTOR EN URBANIZACIÓN GERMAN ASTETE – LA PERLA"** |  | 90d | 2016-04-01 | 2016-06-29 |  |  | 3,095,851.43 |  |  |  |  |  |  |
| 2 | 1.1 | INICIO | milestone | 0d | 2016-04-01 | 2016-04-01 | 90d |  |  |  |  |  |  |  |  |
| 3 | 1.2 | **REDES DE ALCANTARILLADO** |  | 90d | 2016-04-01 | 2016-06-29 |  |  | 2,459,048.31 | 01 |  |  |  |  |  |
| 4 | 1.2.1 | OBRAS PROVISIONALES |  | 89d | 2016-04-01 | 2016-06-28 | 1d |  |  | 01.01 | 000000000000001 |  |  |  |  |
| 5 | 1.2.2 | PLAN DE SEGURIDAD Y SALUD OCUPACIONAL |  | 85d | 2016-04-05 | 2016-06-28 | 1d | start no earlier than 2016-04-05 | 273,539.03 | 01.02 | 000000000000437 | 2740.24 | 9.41 | 25785.66 |  |
| 6 | 1.2.3 | TRABAJOS PRELIMINARES |  | 86d | 2016-04-05 | 2016-06-29 | 0d | start no earlier than 2016-04-05 |  | 01.03 | 000000000000013 | 22187.27 | 0.54 | 11981.13 | 1500 |
| 7 | 1.2.4 | DEMOLICIONES |  | 50d | 2016-04-15 | 2016-06-03 | 26d | start no earlier than 2016-04-15 |  | 01.04 | 000000000000018 | 1348.7 | 13.68 | 18450.22 | 100 |
| 8 | 1.2.5 | MOVIMIENTO DE TIERRAS |  | 66d | 2016-04-15 | 2016-06-19 | 10d | start no earlier than 2016-04-15 |  | 01.05 | 000000000000266 | 66740.1 | 4.78 | 319017.68 | 250 |
| 9 | 1.2.6 | SUMINISTRO E INSTALACION DE TUBERIAS |  | 62d | 2016-04-15 | 2016-06-15 | 14d | start no earlier than 2016-04-15 | 1,281,427.37 | 01.06 | 000000000000096 | 297.59 | 78.56 | 23378.67 | 12 |
| 10 | 1.2.7 | PRUEBA HIDRAULICA Y DE RESISTENCIA |  | 61d | 2016-04-17 | 2016-06-16 | 13d | start no earlier than 2016-04-17 | 68,420.99 | 01.07 | 000000000000104 | 27.92 | 3.36 | 93.81 | 250 |
| 11 | 1.2.8 | BUZONES |  | 60d | 2016-04-17 | 2016-06-15 | 14d | start no earlier than 2016-04-17 | 835,660.92 | 01.08 | 000000000000110 | 27.92 | 5.34 | 149.09 | 20 |
| 12 | 1.3 | **CONEXIONES DOMICILIARIAS DE ALCANTARILLADO** |  | 76d | 2016-04-15 | 2016-06-29 |  |  | 636,803.12 | 02 | 000000000000123 | 3.9 | 439.18 | 1712.8 | 12 |
| 13 | 1.3.1 | TRABAJOS PRELIMINARES Y COMPLEMENTARIOS |  | 76d | 2016-04-15 | 2016-06-29 | 0d | start no earlier than 2016-04-15 |  | 02.01 | 000000000000124 | 52 | 43.96 | 2285.92 | 12 |
| 14 | 1.3.2 | DEMOLICIONES |  | 53d | 2016-04-25 | 2016-06-16 | 13d | start no earlier than 2016-04-25 | 356,909.07 | 02.02 |  |  |  |  |  |
| 15 | 1.3.3 | MOVIMIENTO DE TIERRAS |  | 55d | 2016-04-26 | 2016-06-19 | 10d | start no earlier than 2016-04-26 | 279,894.05 | 02.03 | 000000000000386 |  |  |  |  |
| 16 | 1.3.4 | SUMINISTRO E INSTALACION DE ELEMENTOS PARA CONEXION DOMICILIARIA |  | 54d | 2016-04-25 | 2016-06-17 | 12d | start no earlier than 2016-04-25 |  | 02.04 | 000000000000148 | 20.31 | 25.42 | 516.28 | 100 |
