# Cronograma

Schedule from MS Project, 2016-04-01 to 2016-06-30, costs in S.

## Calendars

- Estándar: Mon-Sun 07:00-12:00, 13:00-16:00.

## Resources

| Resource | Group | Unit | Rate |
| --- | --- | --- | --- |
| MO: Ingeniero residente incl. leyes sociales | Mano de Obra |  | 60.77 |
| MO: Técnico incluye leyes sociales | Mano de Obra |  | 24.36 |
| MO: Topógrafo incl. leyes sociales | Mano de Obra |  | 19.88 |
| MO: Capataz incluye leyes sociales | Mano de Obra |  | 27.54 |
| MO: Dibujante incl. leyes sociales | Mano de Obra |  | 21.87 |
| MO: Operador de maquinaria-equipo pesado | Mano de Obra |  | 20.12 |
| MO: Operario incluye leyes sociales | Mano de Obra |  | 19.3 |
| MO: Oficial incluye leyes sociales | Mano de Obra |  | 16.01 |
| MO: Peon incluye leyes sociales | Mano de Obra |  | 14.4 |
| Alambre negro N° 8 | Material | kg | 2.21 |
| Alambre negro N° 16 | Material | kg | 2.21 |
| Clavo c/cabeza para madera (promedio) | Material | kg | 3.01 |
| Perno incluye tuerca 3/4" x 6" | Material | und | 4.59 |
| Tirafón hexagonal acero sae 1020 de 1 1/2" x 1/4" | Material | und | 1.52 |
| Tornillo acero sae 1020 1 1/2" x 1/4" | Material | und | 0.7 |
| Fo. construcción : (costo promedio) | Material | kg | 2.4 |
| Arena fina | Material | m3 | 40.45 |
| Arena gruesa | Material | m3 | 47.49 |
| Tierra seleccionada | Material | m3 | 52.16 |
| Material granular S. A1a-A1b AASHTO | Material | m3 | 46.23 |
| Piedra partida-grava de 1/2" - 3/4" | Material | m3 | 51.38 |
| Cable eléctrico TW de 2 5 mm2 ( 7 alambres) | Material |  | 0.77 |
| Ducha cromada incl. grifería 1 llave | Material | und | 34.7 |
| Lavatorio de losa i/ grifo crom. 1 caño | Material | und | 90 |
| Baño portatil (alquiler) incl. mantemiento mensual por unidad | Material | und | 226.89 |
| Fluorescente circul. 32 w c/equipo+pant. | Material | und | 29.4 |
| Caja de fierro galv. rectang. 4" x 2 1/8" | Material | und | 0.68 |
| Caja de fierro galv. octogonal 4"x 2 1/8" | Material | und | 0.77 |
| Lámpara destellante | Material | und | 2.12 |
| Reja by pass de 3.00 m x 1.5 m con barras 1 1/2"x5/16" @ 50mm de acero inox. 304 | Material | und | 2.12 |
| Asfalto líquido RC 250 (galón) | Material | und | 17.82 |
| Asfalto caliente (en planta) | Material | m3 | 365 |
| Ladrillo de arcilla king kong(a máquina) | Material | und | 0.47 |
| Cemento portland I sector público; en bolsa | Material | und | 16.33 |
| Cemento portland V sector público; en bolsa | Material | und | 21.36 |
| Bisagra de fierro (promedio) | Material | und | 6.73 |
| Candado incl.aldabas | Material | und | 19.03 |
| Cerrojo t/picaporte incl. accesorios | Material | und | 15.35 |
| Anillo jebe p/tuber. PVC UF DN 150 mm | Material | und | 3.45 |
| Cal de obra en bolsa | Material | und | 7 |
| Cinta plástica para señal de seguridad de obra | Material |  | 0.12 |
| Cinta selladora teflón | Material | und | 1.23 |
| Copias de planos | Material | m2 | 4.35 |
| Segundo original de plano | Material | m2 | 12.71 |
| Papel-copia xeros tamaño A4 | Material | und | 0.1 |
| Tanque fibra vidrio de 1000 litros | Material | und | 419 |
| Pegamento para tubo de PVC 1/4 galón | Material | und | 31.95 |
| Agua incluye transporte a pie de obra (Camión cisterna y Motobomba) | Material | m3 | 10 |
| Grass y/o arbustos de tallo corto | Material | m2 | 2.25 |
| Yeso (bolsa) | Material | und | 7.5 |
| Prueba: Control de compactación (densidad de campo) | Material | und | 56 |
| Prueba: proctor modificado de campo | Material | und | 120 |
| Chema 1 en polvo bolsa por kg (impermeabilizante para concreto) | Material | und | 6.53 |
| Sika:plastiment HE98 balde de 20 kg | Material | und | 97.05 |
| Hipoclorito de calcio al 70% | Material | kg | 19.98 |
| Caja de concreto 0 30 m x 0 60 m para desagüe (base intermedio y marco) | Material | und | 35.08 |
| Cuerpo intermedio de 0 30x0 30x0 60 m p/caja concreto -CD (adic. p/caja prof.) | Material | und | 22 |
| Tapa de concreto armado perfil FF de 0 60 m | Material | und | 65 |
| Tapa concreto armado caja para desague de 0 30 m x 0 6 m | Material | und | 19.39 |
| Flete-transporte de tubería liviana no metálica (PVC HDPE GRP ó similar) | Material | kg | 0.04 |
| Flete accesorio de abrazadera DN 200 mm - 250 mm | Material | und | 1.19 |
| Gasolina de 84 octanos (por galón) | Material | und | 9.91 |
| Agua incluye transporte a pie de obra (Camión cisterna y Motobomba) | Material | m3 | 10 |
| Loseta corriente de 0 20 x 0 20 m | Material | m2 | 26.5 |
| Madera para encofrado y carpintería | Material | p2 | 3.8 |
| Regla de madera tipo tornillo especial | Material | und | 31.25 |
| Ventana de madera corrediza incl cerradura | Material | m2 | 35 |
| Triplay de espesor 4 mm | Material | m2 | 8.68 |
| Triplay de espesor 6 mm | Material | m2 | 12.15 |
| Marco de fierro fundido de diámetro 0 60 m | Material | und | 150 |
| Kerosene para uso industrial envase por galón | Material | und | 13.5 |
| Pintura esmalte sintético envase por galón | Material | und | 60 |
| Pintura esmalte sintético anticorrosivo envase por galón | Material | und | 33.08 |
| Plancha negra LAF 0 50 x 920 x 2400mm | Material | und | 125.3 |
| Plancha de fibro cemento perfil 4 4mm | Material | und | 31.24 |
| Tapón fo. galvanizado UR DN 15 mm (m - h) | Material | und | 0.81 |
| Tapón de acero DN 150 mm | Material | und | 112.83 |
| Tapón de acero DN 200 mm | Material | und | 170.27 |
| Tapón de acero DN 250 mm | Material | und | 216.09 |
| Tapón de acero DN 300 mm | Material | und | 324.94 |
| Codo de PVC UR 45° DN 15 mm | Material | und | 0.92 |
| Codo de PVC UF 45° DN 150 mm | Material | und | 129.74 |
| Codo de PVC 90° DN 15 mm | Material | und | 139.86 |
| Lubricante para tuberia de unión flexible; (galón) | Material | und | 49.87 |
| Tapón de PVC simple presión DN 20 mm | Material | und | 0.84 |
| Tee PVC unión rosca DN 15 mm | Material | und | 1.31 |
| Tubo de PVC SP PN 5 DN 200 mm | Material |  | 33.81 |
| Tubo de PVC SP PN 10 DN 15 mm | Material |  | 1.03 |
| Tubo de PVC SP PN 10 D 11/2" | Material |  | 0.99 |
| Unión de PVC presión-rosca DN 15 mm | Material | und | 0.59 |
| Marco y Tapa termoplastico p/ medidor de agua de 1/2" y 3/4" (CTPS-E-004:2005 ó su actualización) | Material | und | 39 |
| Caja incluye solado termoplastico p/ medidor de agua de 15 (1/2") y 20 (3/4") (CTPS-E-004:2005 ó su actualización) | Material | und | 25 |
| Tubo de PVC UF norma ISO 4435 SN 2 DN 150 mm | Material |  | 15.34 |
| Conexiones a caja PVC SAP DN 20 mm | Material | und | 0.34 |
| Curva PVC SAP de 90° DN 20 mm | Material | und | 1.6 |
| Tubo de PVC SAP DN 20 mm | Material |  | 1.54 |
| TUBERIA HDPE NTP ISO 8772:2009 SN-2 DN = 200 mm | Material |  | 82.96 |
| TUBERIA HDPE NTP ISO 8772:2009 SN-2 DN = 250 mm | Material |  | 129.28 |
| TUBERIA HDPE NTP ISO 8772:2009 SN-2 DN = 315 mm | Material |  | 205.12 |
| Abrazadera de polietileno DN 200 x Salida 160mm para conex. alcantarillado s/especif. | Material | und | 62 |
| Abrazadera de polietileno DN 250 x Salida 160mm para conex. alcantarillado s/especif. | Material | und | 135 |
| Pasamuro de HDPE DN 250 mm | Material | und | 545.5 |
| Pasamuro de HDPE DN 200 mm | Material | und | 469.8 |
| Herramientas complementarias (% MO) | Equipo |  | 8 |
| Balde para prueba hidrostático incluye accesorios | Equipo |  | 0.35 |
| Cizalla para corte de fierro | Equipo |  | 2 |
| Tarraja para tubería de fo. galvanizado - pvc | Equipo |  | 1.55 |
| Tecle t/trípode inc. cadena para 5 tonel. | Equipo |  | 2.6 |
| Prueba: rotura de probeta | Equipo |  | 10 |
| Andamio de metal y/o de madera (alquiler) | Equipo |  | 1.56 |
| Camión cisterna 4x2 (agua) 122HP 1500gal | Equipo |  | 124.02 |
| Camión volquete 4x2 140 - 210 HP 6m3 | Equipo |  | 151.75 |
| Camión volquete 4x2 210 - 280 HP 8m3 | Equipo |  | 182.94 |
| Camioneta pick-up 4x2 simple 1000 kg 90 HP | Equipo |  | 40.63 |
| Camioneta pick-up 4 x 2 simple 2000 kg 90 HP | Equipo |  | 40.63 |
| Encofrado metálico p/construcción cajas-similar | Equipo |  | 2.32 |
| Nivel topográfico AFL320 E=0 3" con trípode y accesorios | Equipo |  | 7.77 |
| Equipo de estación total precisión 5" G608M ó similar incl.prismas jalones telescópicos | Equipo |  | 21.17 |
| Equipo de cómputo incluye software | Equipo |  | 21.17 |
| Mezcladora concreto t/tambor23HP 11-12p3 | Equipo |  | 28.96 |
| Motobomba 5 HP de 2" incluye manguera | Equipo |  | 7.56 |
| Motobomba 10 HP de 4" incluye manguera | Equipo |  | 11.79 |
| Camión concretero 6x4 235-300HP 8m3 | Equipo |  | 244.42 |
| Camión imprimador 6x2 178-210H de 1800 galones | Equipo |  | 208.68 |
| Cargador sob. llanta 80-95HP 1 5-1 75 Yd3 | Equipo |  | 124.95 |
| Cargador retroexcava dor 0 5-0 75Yd3 62HP | Equipo |  | 108.34 |
| Compactadora vibrat. de plancha 4 HP | Equipo |  | 7.51 |
| Compactadora vibrat. de plancha 7 HP | Equipo |  | 13.16 |
| Compresora neumática 76 HP 125 - 175 pcm. | Equipo |  | 44.87 |
| Compresora neumática 87 HP 250 - 330 pcm. | Equipo |  | 56.78 |
| Planta-Dosificadora de concreto PM (planta) | Equipo |  | 96.2 |
| Martillo neumático 21 - 24 kg | Equipo |  | 5.67 |
| Martillo neumático 25 - 29 kg | Equipo |  | 4.81 |
| Martillo cincel para corte-demolición | Equipo |  | 3.28 |
| Motoniveladora de 85 - 120 HP | Equipo |  | 98.03 |
| Pavimentadora sobre oruga 69HP 10 pies | Equipo |  | 116.41 |
| Rodillo liso vibrat. 0 8-1 1 ton manual ó de control remoto | Equipo |  | 15.82 |
| Rodillo neumático autoprop. 60-80 HP 3 - 5 ton | Equipo |  | 74.96 |
| Rodillo tandem estático autopropulsado 30 - 57 HP 3 - 5 ton | Equipo |  | 29.21 |
| Rodillo tandem vibratorio autopropulsado 15-35HP 2 5 - 4 ton | Equipo |  | 32 |
| Cortadora de pavimento C35-35HP i/combus | Equipo |  | 19.7 |
| Disco para corte PC 300 de 18" | Equipo |  | 1979.95 |
| Taladro eléctrico incluye broca | Equipo |  | 0.75 |
| Tractor sobre oruga 140 - 160 HP | Equipo |  | 237.73 |
| Vibrador de concreto 4 HP 18PL | Equipo |  | 8.03 |
| Vibrador de concreto 4 HP 18PL (1 5") | Equipo |  | 8 |
| Programa de inspecciones planeadas | Subcontrato | glb | 3620 |
| Autorización de centro de acopio para disposición final de residuos solidos (Tuberias de concreto p/desague) | Subcontrato | m3 | 18 |
| Autorizacion de centro de acopio para disposicion final de residuos peligrosos | Subcontrato | m3 | 18 |
| Autorización de centro de acopio para disposición final de residuos solidos (material desmonte no peligroso) | Subcontrato | m3 | 18 |
| Plan de contingencias | Subcontrato | glb | 5678 |
| Programa de Induccion capacitacion y entrenamiento | Subcontrato | glb | 4250 |
| Programa de registro notificacion e investigacion de accidentes | Subcontrato | glb | 3560 |
| Programa de identificacion y control de riesgos higienicos | Subcontrato | glb | 10551 |
| Programa de manejo de materiales peligrosos en obra | Subcontrato | glb | 3260 |
| Programa de mantenimiento preventivo de maquinaria y equipos | Subcontrato | glb | 1860 |
| Medicion y seguimiento del desempeño y monitoreo en SST | Subcontrato | glb | 10160 |
| Servicio de termofusión para unir tubería HDPE DN 250 pared lisa (Inl. equipo termofusión y G.E. costo prorrateo por m | Subcontrato | und | 64.42 |
| Servicio de termofusión para unir tubería HDPE DN 315 pared lisa (Inl. equipo termofusión y G.E. costo prorrateo por m | Subcontrato | und | 69.03 |

## Schedule

| ID | WBS | Task | Duration | Start | Finish | Predecessors | Total slack | Free slack | Constraint | Resources | Work | Cost | Text1 | Text8 | Text3 | Text4 | Text2 | Text6 |
| --- | --- | --- | --- | --- | --- | --- | --- | --- | --- | --- | --- | --- | --- | --- | --- | --- | --- | --- |
| 1 | 1 | **CAMBIO DE COLECTOR EN LA URB. GERMAN ASTETE** | 90d | 2016-04-01 | 2016-06-30 |  |  |  |  |  | 1192151h | 31,882,606.48 | 01 | 000000000001120 |  |  |  |  |
| 2 | 1.1 | **OBRAS PROVISIONALES** | 89d | 2016-04-01 | 2016-06-29 |  | 0d |  |  |  | 66767.2h | 4,568,645.35 | 01.01 | 000000000001121 |  |  |  |  |
| 3 | 1.1.1 | Campamento provisional para la obra tipo AD-03 | 4d | 2016-04-01 | 2016-04-05 |  | 0d |  | start no earlier than 2015-09-30 | MO: Capataz incluye leyes sociales [70.6%]; MO: Operador de maquinaria-equipo pesado [3.2%]; MO: Operario incluye leyes sociales [770.4%]; MO: Oficial incluye leyes sociales [323.4%]; MO: Peon incluye leyes sociales [819.1%]; Cizalla para corte de fierro [10.9%]; Tarraja para tubería de fo. galvanizado - pvc [8.3%]; Andamio de metal y/o de madera (alquiler) [171%]; Mezcladora concreto t/tambor23HP 11-12p3 [3.2%]; Taladro eléctrico incluye broca [58.5%]; Vibrador de concreto 4 HP 18PL (1 5") [5%]; Alambre negro N° 8 [0.36 kg]; Alambre negro N° 16 [1.6 kg]; Clavo c/cabeza para madera (promedio) [1.33 kg]; Fo. construcción : (costo promedio) [33.6 kg]; Cable eléctrico TW de 2 5 mm2 ( 7 alambres) [1222.5%]; Tubo de PVC SP PN 10 DN 15 mm [45%]; Tubo de PVC SAP DN 20 mm [600%]; Ventana de madera corrediza incl cerradura [0.24 m2]; Triplay de espesor 4 mm [11.52 m2]; Arena fina [0.22 m3]; Arena gruesa [1.13 m3]; Piedra partida-grava de 1/2" - 3/4" [1.56 m3]; Agua incluye transporte a pie de obra (Camión cisterna y Motobomba) [0.1 m3]; Agua incluye transporte a pie de obra (Camión cisterna y Motobomba) [0.46 m3]; Madera para encofrado y carpintería [102.63 p2]; Tirafón hexagonal acero sae 1020 de 1 1/2" x 1/4" [1.39 und]; Tornillo acero sae 1020 1 1/2" x 1/4" [1.39 und]; Ducha cromada incl. grifería 1 llave [0.1 und]; Lavatorio de losa i/ grifo crom. 1 caño [0.1 und]; Fluorescente circul. 32 w c/equipo+pant. [0.3 und]; Caja de fierro galv. rectang. 4" x 2 1/8" [1.05 und]; Caja de fierro galv. octogonal 4"x 2 1/8" [1.05 und]; Lámpara destellante [0.4 und]; Reja by pass de 3.00 m x 1.5 m con barras 1 1/2"x5/16" @ 50mm de acero inox. 304 [0.2 und]; Ladrillo de arcilla king kong(a máquina) [257.76 und]; Cemento portland I sector público; en bolsa [19.67 und]; Bisagra de fierro (promedio) [2.1 und]; Candado incl.aldabas [0.7 und]; Cerrojo t/picaporte incl. accesorios [0.7 und]; Cinta selladora teflón [0.02 und]; Tanque fibra vidrio de 1000 litros [0.05 und]; Chema 1 en polvo bolsa por kg (impermeabilizante para concreto) [2.42 und]; Pintura esmalte sintético envase por galón [0.98 und]; Plancha de fibro cemento perfil 4 4mm [0.36 und]; Codo de PVC UR 45° DN 15 mm [0.4 und]; Tapón de PVC simple presión DN 20 mm [0.15 und]; Tee PVC unión rosca DN 15 mm [0.2 und]; Unión de PVC presión-rosca DN 15 mm [0.4 und]; Conexiones a caja PVC SAP DN 20 mm [3 und]; Curva PVC SAP de 90° DN 20 mm [1.5 und] | 717.98h | 12,358.54 | 01.01.01 | 000000000001122 | 4173.75 | 4173.75 |  |  |
| 4 | 1.1.2 | Cartel de identificación de la obra de 3,60 m x 1,80 m | 5d | 2016-04-05 | 2016-04-10 |  | 1d | 0d | start no earlier than 2016-04-05 | MO: Capataz incluye leyes sociales [10%]; MO: Operario incluye leyes sociales [200%]; MO: Peon incluye leyes sociales [200%]; Clavo c/cabeza para madera (promedio) [0.75 kg]; Triplay de espesor 6 mm [6.48 m2]; Madera para encofrado y carpintería [70 p2]; Perno incluye tuerca 3/4" x 6" [9 und]; Cemento portland I sector público; en bolsa [0.9 und]; Pintura esmalte sintético envase por galón [0.32 und]; Pintura esmalte sintético anticorrosivo envase por galón [0.32 und]; Plancha negra LAF 0 50 x 920 x 2400mm [3 und] | 164h | 3,615.21 | 01.01.02 | 000000000001123 | 1381.51 | 1381.51 |  |  |
| 5 | 1.1.3 | Movilización de campamentos,maquinarias, herramientas | 4d | 2016-04-05 | 2016-04-09 | 4SS | 1d | 0d | start no earlier than 2015-09-30 | MO: Capataz incluye leyes sociales [10%]; MO: Operador de maquinaria-equipo pesado [200%]; MO: Peon incluye leyes sociales; Camión volquete 4x2 140 - 210 HP 6m3; Camioneta pick-up 4 x 2 simple 2000 kg 90 HP | 163.2h | 7,992.77 | 01.01.03 | 000000000001124 | 2007.37 | 2007.37 |  |  |
| 6 | 1.1.4 | Servicio de agua potable para los campamentos (estimado global) | 85d | 2016-04-05 | 2016-06-29 | 5SS | 1d | 0d | start no earlier than 2015-09-30 | MO: Operador de maquinaria-equipo pesado [4500%]; Camión cisterna 4x2 (agua) 122HP 1500gal [4500%] | 61200h | 4,410,684 | 01.01.04 | 000000000001125 | 8648.4 | 51890.4 |  |  |
| 7 | 1.1.5 | Servicio de baño portátil (inodoro y lavadero) | 85d | 2016-04-05 | 2016-06-29 | 6SS | 1d | 0d | start no earlier than 2015-09-30 | Baño portatil (alquiler) incl. mantemiento mensual por unidad [6 und] |  | 1,361.34 | 01.01.05 | 000000000001126 | 226.89 | 1361.34 |  |  |
| 8 | 1.1.6 | Limpieza permanente de la obra | 85d | 2016-04-05 | 2016-06-29 | 7SS | 1d | 0d | start no earlier than 2015-09-30 | MO: Capataz incluye leyes sociales [10%]; MO: Peon incluye leyes sociales [200%] | 1428h | 21,456.72 | 01.01.06 | 000000000001127 | 257.48 | 257.48 |  |  |
| 9 | 1.1.7 | Riego de zona de trabajo para mitigar la contaminación -polvo (con autorización de uso de grifo) | 85d | 2016-04-05 | 2016-06-29 | 8SS | 1d | 0d | start no earlier than 2015-09-30 | MO: Capataz incluye leyes sociales [8.9%]; MO: Operador de maquinaria-equipo pesado [89.2%]; MO: Peon incluye leyes sociales [178.4%]; Camión cisterna 4x2 (agua) 122HP 1500gal [89.2%]; Motobomba 5 HP de 2" incluye manguera [89.2%] | 3094.07h | 111,176.76 | 01.01.07 | 000000000001128 | 1.46 | 5210.32 | 3568.71 | 1000 |
| 10 | 1.1.8 | Mitigacion de Impactos Ambientales | 85d | 2016-04-05 | 2016-06-29 | 9SS | 1d | 0d |  |  |  |  | 01.01.08 |  |  |  |  |  |
| 11 | 1.1.9 | Plan de tránsito vehicular y peatonal durante la obra | 85d | 2016-04-05 | 2016-06-29 | 10SS | 1d | 0d |  |  |  |  | 01.01.09 |  |  |  |  |  |
| 12 | 1.2 | **PLAN SEGURIDAD Y SALUD OCUPACIONAL** | 85d | 2016-04-05 | 2016-06-29 |  | 1d |  |  |  |  | 42,939 | 01.02 | 000000000001129 |  |  |  |  |
| 13 | 1.2.1 | Planes de Seguridad y salud ocupacional | 85d | 2016-04-05 | 2016-06-29 | 11SS | 1d |  | start no earlier than 2015-09-30 | Plan de contingencias [1 glb]; Programa de Induccion capacitacion y entrenamiento [1 glb]; Programa de registro notificacion e investigacion de accidentes [1 glb]; Programa de identificacion y control de riesgos higienicos [1 glb]; Programa de manejo de materiales peligrosos en obra [1 glb]; Programa de mantenimiento preventivo de maquinaria y equipos [1 glb]; Medicion y seguimiento del desempeño y monitoreo en SST [1 glb]; Programa de inspecciones planeadas [1 glb] |  | 42,939 | 01.02.01 | 000000000001130 | 42939 | 42939 |  |  |
| 14 | 1.3 | **TRABAJOS PRELIMINARES** | 86d | 2016-04-05 | 2016-06-30 |  | 0d |  |  |  | 5454.36h | 77,187.67 | 01.03 | 000000000001131 |  |  |  |  |
| 15 | 1.3.1 | Trazo y replanteo inicial del proyecto, para líneas-redes | 10d | 2016-04-05 | 2016-04-15 | 3 | -5d | 0d | start no earlier than 2015-09-30 | MO: Técnico incluye leyes sociales [105%]; MO: Topógrafo incl. leyes sociales [105%]; MO: Capataz incluye leyes sociales [7%]; MO: Peon incluye leyes sociales [210%]; Nivel topográfico AFL320 E=0 3" con trípode y accesorios [70%]; Equipo de estación total precisión 5" G608M ó similar incl.prismas jalones telescópicos [70%]; Equipo de cómputo incluye software [70%]; Fo. construcción : (costo promedio) [21.42 kg]; Cal de obra en bolsa [24.99 und]; Pintura esmalte sintético envase por galón [1.18 und] | 509.6h | 9,392.76 | 01.03.01 | 000000000001132 | 858.1 | 3063.42 | 3.57 | 1.7 |
| 16 | 1.3.2 | Replanteo final de la obra, para líneas redes con estación total | 10d | 2016-06-20 | 2016-06-30 | 59 | 0d |  | start no earlier than 2016-06-20 | MO: Técnico incluye leyes sociales [52.5%]; MO: Topógrafo incl. leyes sociales [52.5%]; MO: Capataz incluye leyes sociales [5.2%]; MO: Dibujante incl. leyes sociales [26.3%]; MO: Peon incluye leyes sociales [105%]; Nivel topográfico AFL320 E=0 3" con trípode y accesorios [52.5%]; Equipo de estación total precisión 5" G608M ó similar incl.prismas jalones telescópicos [52.5%]; Equipo de cómputo incluye software [52.5%]; Copias de planos [13.39 m2]; Segundo original de plano [2.68 m2] | 319.2h | 5,839.48 | 01.03.02 | 000000000001133 | 351.89 | 1256.25 | 3.57 | 3.4 |
| 17 | 1.3.3 | Desvío de aguas servidas incl. bombeo y alquiler de tubo p/mantenim. servicio DN 200-250 mm | 60d | 2016-04-15 | 2016-06-14 | 15 | 16d | 0d | start no earlier than 2015-09-30 | MO: Capataz incluye leyes sociales [9.5%]; MO: Operario incluye leyes sociales [95.4%]; MO: Peon incluye leyes sociales [95.4%]; Motobomba 10 HP de 4" incluye manguera [763.3%]; Tubo de PVC SP PN 5 DN 200 mm [4293.5%]; Arena gruesa [8.59 m3]; Cemento portland I sector público; en bolsa [8.59 und]; Yeso (bolsa) [8.59 und] | 4625.56h | 61,955.43 | 01.03.03 | 000000000001134 | 11.73 | 20145.22 | 1717.41 | 100 |
| 18 | 1.3.4 | Desvío de aguas servidas incl. Bombeo y alquiler de tubo p/mantenim. Servicio DN 300-350 mm | 60d | 2016-04-15 | 2016-06-14 | 17SS | 16d |  |  |  |  |  | 01.03.04 |  |  |  |  |  |
| 19 | 1.4 | **DEMOLICIONES** | 50d | 2016-04-15 | 2016-06-04 |  | 14d |  |  |  | 323415h | 9,458,021.18 | 01.04 | 000000000001135 |  |  |  |  |
| 20 | 1.4.1 | **PAVIMENTOS, VEREDAS Y SARDINELES** | 50d | 2016-04-15 | 2016-06-04 |  | 14d |  |  |  | 300499h | 8,873,830.23 | 01.04.01 | 000000000001136 |  |  |  |  |
| 21 | 1.4.1.1 | Corte+rotura, ED y reposic. De pavimento flexible asfalto caliente de e= 2" (incl. Pago por disp. Final) | 45d | 2016-04-15 | 2016-05-30 | 15 | 14d | 0d | start no earlier than 2015-09-30 | MO: Capataz incluye leyes sociales [568.7%]; MO: Operador de maquinaria-equipo pesado [7543.5%]; MO: Operario incluye leyes sociales [1774.2%]; MO: Peon incluye leyes sociales [19490.1%]; Camión volquete 4x2 140 - 210 HP 6m3 [1323.1%]; Camión volquete 4x2 210 - 280 HP 8m3 [1089.3%]; Camioneta pick-up 4x2 simple 1000 kg 90 HP [1085%]; Cargador sob. llanta 80-95HP 1 5-1 75 Yd3 [168%]; Compactadora vibrat. de plancha 4 HP [227.5%]; Compactadora vibrat. de plancha 7 HP [923.5%]; Compresora neumática 76 HP 125 - 175 pcm. [295.7%]; Martillo neumático 21 - 24 kg [568.6%]; Martillo cincel para corte-demolición [568.6%]; Motoniveladora de 85 - 120 HP [166%]; Pavimentadora sobre oruga 69HP 10 pies [227.5%]; Rodillo neumático autoprop. 60-80 HP 3 - 5 ton [393.5%]; Rodillo tandem estático autopropulsado 30 - 57 HP 3 - 5 ton [227.5%]; Rodillo tandem vibratorio autopropulsado 15-35HP 2 5 - 4 ton [166%]; Cortadora de pavimento C35-35HP i/combus [2274.6%]; Material granular S. A1a-A1b AASHTO [454.91 m3]; Asfalto caliente (en planta) [118.28 m3]; Agua incluye transporte a pie de obra (Camión cisterna y Motobomba) [376.67 m3]; Autorización de centro de acopio para disposición final de residuos solidos (Tuberias de concreto p/desague) [1 m3]; Autorizacion de centro de acopio para disposicion final de residuos peligrosos [1 m3]; Asfalto líquido RC 250 (galón) [200.16 und]; Kerosene para uso industrial envase por galón [145.57 und]; Disco para corte PC 300 de 18" [22.7%] | 140773h | 4,227,006.67 | 01.04.01.01 | 000000000001137 | 97.54 | 177488.66 | 1819.65 |  |
| 22 | 1.4.1.2 | Corte+rotura, ED y reposición de vereda rígida f'c 175 kg/cm2 de 10 cm espesor | 45d | 2016-04-15 | 2016-05-30 | 21SS | 31d | 0d | start no earlier than 2015-09-30 | MO: Ingeniero residente incl. leyes sociales [37.7%]; MO: Técnico incluye leyes sociales [37.7%]; MO: Capataz incluye leyes sociales [629.6%]; MO: Operador de maquinaria-equipo pesado [8309.2%]; MO: Operario incluye leyes sociales [5792%]; MO: Oficial incluye leyes sociales [1219.1%]; MO: Peon incluye leyes sociales [17866.2%]; Camión volquete 4x2 210 - 280 HP 8m3 [615.8%]; Camioneta pick-up 4x2 simple 1000 kg 90 HP [1012.5%]; Camión concretero 6x4 235-300HP 8m3 [1390.8%]; Cargador sob. llanta 80-95HP 1 5-1 75 Yd3 [160.9%]; Compactadora vibrat. de plancha 7 HP [532%]; Compresora neumática 76 HP 125 - 175 pcm. [383.5%]; Planta-Dosificadora de concreto PM (planta) [37.7%]; Martillo neumático 21 - 24 kg [738.1%]; Martillo cincel para corte-demolición [738.1%]; Motoniveladora de 85 - 120 HP [161.8%]; Rodillo neumático autoprop. 60-80 HP 3 - 5 ton [161.8%]; Rodillo tandem vibratorio autopropulsado 15-35HP 2 5 - 4 ton [161.8%]; Cortadora de pavimento C35-35HP i/combus [2954.7%]; Vibrador de concreto 4 HP 18PL [1181.4%]; Arena gruesa [99.38 m3]; Material granular S. A1a-A1b AASHTO [221.66 m3]; Piedra partida-grava de 1/2" - 3/4" [137.16 m3]; Agua incluye transporte a pie de obra (Camión cisterna y Motobomba) [656.11 m3]; Agua incluye transporte a pie de obra (Camión cisterna y Motobomba) [39.39 m3]; Madera para encofrado y carpintería [874.23 p2]; Cemento portland I sector público; en bolsa [1630.35 und]; Sika:plastiment HE98 balde de 20 kg [17.94 und]; Regla de madera tipo tornillo especial [17.73 und]; Disco para corte PC 300 de 18" [22.2%] | 158921h | 4,630,784.44 | 01.04.01.02 | 000000000001138 | 92.3 | 163673.74 | 1773.28 |  |
| 23 | 1.4.1.3 | Corte+rotura, ED y reposic. de pavimento flexible asfalto caliente de e= 2" (incl. Pago por disp. Final) | 45d | 2016-04-15 | 2016-05-30 | 22SS | 31d |  |  |  |  |  | 01.04.01.03 |  |  |  |  |  |
| 24 | 1.4.1.4 | Reposición de jardines | 50d | 2016-04-15 | 2016-06-04 |  | 26d |  | start no earlier than 2016-04-15 | MO: Capataz incluye leyes sociales [9.6%]; MO: Peon incluye leyes sociales [191.8%]; Grass y/o arbustos de tallo corto [251.7 m2]; Tierra seleccionada [62.32 m3]; Agua incluye transporte a pie de obra (Camión cisterna y Motobomba) [11.99 m3] | 805.43h | 16,039.13 | 01.04.01.04 | 000000000001295 | 21.47 | 5146.57 | 239.71 | 50 |

| ID | WBS | Task | Duration | Start | Finish | Predecessors | Total slack | Free slack | Constraint | Resources | Work | Cost | Text1 | Text8 | Text2 | Text3 | Text4 | Text6 |
| --- | --- | --- | --- | --- | --- | --- | --- | --- | --- | --- | --- | --- | --- | --- | --- | --- | --- | --- |
| 25 | 1.4.2 | **BUZONES** | 49d | 2016-04-16 | 2016-06-04 |  | 14d |  |  |  | 22915.8h | 584,190.95 | 01.04.02 | 000000000001140 |  |  |  |  |
| 26 | 1.4.2.1 | Demolición de buzón de mal estado, de 1,01 a 1,25 m de profundidad (incl. Eliminacion desmonte en centro acopio autorizado) | 45d | 2016-04-16 | 2016-05-31 | 21SS+1d | 14d | 0d | start no earlier than 2015-09-30 | MO: Capataz incluye leyes sociales [8.5%]; MO: Operador de maquinaria-equipo pesado [106.1%]; MO: Operario incluye leyes sociales [84.8%]; MO: Oficial incluye leyes sociales [84.8%]; MO: Peon incluye leyes sociales [169.7%]; Camioneta pick-up 4x2 simple 1000 kg 90 HP [21.2%]; Compresora neumática 76 HP 125 - 175 pcm. [84.8%]; Martillo neumático 21 - 24 kg [84.8%]; Martillo cincel para corte-demolición [84.8%] | 2626.92h | 47,648.59 | 01.04.02.01 | 000000000001296 | 14 | 459.13 | 6427.82 | 2.75 |
| 27 | 1.4.2.2 | Demolición de buzón de mal estado, de 1,26 a 1,50 m de profundidad (incl. Eliminacion desmonte en centro acopio autorizado) | 45d | 2016-04-16 | 2016-05-31 | 26SS | 24d | 0d | start no earlier than 2015-09-30 | MO: Capataz incluye leyes sociales [8.8%]; MO: Operador de maquinaria-equipo pesado [121.4%]; MO: Operario incluye leyes sociales [86.7%]; MO: Oficial incluye leyes sociales [86.7%]; MO: Peon incluye leyes sociales [176.6%]; Camión volquete 4x2 210 - 280 HP 8m3 [11.4%]; Camioneta pick-up 4x2 simple 1000 kg 90 HP [21.7%]; Cargador sob. llanta 80-95HP 1 5-1 75 Yd3 [1.6%]; Compresora neumática 76 HP 125 - 175 pcm. [86.7%]; Martillo neumático 21 - 24 kg [86.7%]; Martillo cincel para corte-demolición [86.7%]; Autorización de centro de acopio para disposición final de residuos solidos (material desmonte no peligroso) [1 m3] | 2789.58h | 58,078.17 | 01.04.02.02 | 000000000001141 | 13 | 654.32 | 8506.16 | 2.5 |
| 28 | 1.4.2.3 | Demolición de buzón de mal estado, de 1,51 a 1,75 m de profundidad (incl. eliminacion desmonte en centro acopio autorizado) | 45d | 2016-04-16 | 2016-05-31 | 27SS | 24d | 0d | start no earlier than 2015-09-30 | MO: Capataz incluye leyes sociales [9.7%]; MO: Operador de maquinaria-equipo pesado [133.3%]; MO: Operario incluye leyes sociales [95.2%]; MO: Oficial incluye leyes sociales [95.2%]; MO: Peon incluye leyes sociales [194%]; Camión volquete 4x2 210 - 280 HP 8m3 [12.4%]; Camioneta pick-up 4x2 simple 1000 kg 90 HP [23.8%]; Cargador sob. llanta 80-95HP 1 5-1 75 Yd3 [1.8%]; Compresora neumática 76 HP 125 - 175 pcm. [95.2%]; Martillo neumático 21 - 24 kg [95.2%]; Martillo cincel para corte-demolición [95.2%]; Autorización de centro de acopio para disposición final de residuos solidos (material desmonte no peligroso) [1 m3] | 3064.47h | 63,730.47 | 01.04.02.03 | 000000000001142 | 15 | 725.59 | 10883.85 | 2.25 |
| 29 | 1.4.2.4 | Demolición de buzón de mal estado, de 1,76 a 2,00 m de profundidad (incl. eliminacion desmonte en centro acopio autorizado) | 45d | 2016-04-16 | 2016-05-31 | 26SS | 14d | 0d | start no earlier than 2015-09-30 | MO: Capataz incluye leyes sociales [9.6%]; MO: Operador de maquinaria-equipo pesado [131.7%]; MO: Operario incluye leyes sociales [94.4%]; MO: Oficial incluye leyes sociales [94.4%]; MO: Peon incluye leyes sociales [192.3%]; Camión volquete 4x2 210 - 280 HP 8m3 [12%]; Camioneta pick-up 4x2 simple 1000 kg 90 HP [23.6%]; Cargador sob. llanta 80-95HP 1 5-1 75 Yd3 [1.7%]; Compresora neumática 76 HP 125 - 175 pcm. [94.4%]; Martillo neumático 21 - 24 kg [94.4%]; Martillo cincel para corte-demolición [94.4%]; Autorización de centro de acopio para disposición final de residuos solidos (material desmonte no peligroso) [1 m3] | 3035.55h | 62,902.03 | 01.04.02.04 | 000000000001143 | 17 | 810.87 | 13784.79 |  |
| 30 | 1.4.2.5 | Demolición de buzón de mal estado, de 2,01 a 2,50 m de profundidad (incl. eliminacion desmonte en centro acopio autorizado) | 45d | 2016-04-16 | 2016-05-31 | 29SS | 14d | 0d | start no earlier than 2015-09-30 | MO: Capataz incluye leyes sociales [10.2%]; MO: Operador de maquinaria-equipo pesado [139.2%]; MO: Operario incluye leyes sociales; MO: Oficial incluye leyes sociales; MO: Peon incluye leyes sociales [203.6%]; Camión volquete 4x2 210 - 280 HP 8m3 [12.4%]; Camioneta pick-up 4x2 simple 1000 kg 90 HP [25%]; Cargador sob. llanta 80-95HP 1 5-1 75 Yd3 [1.8%]; Compresora neumática 76 HP 125 - 175 pcm.; Martillo neumático 21 - 24 kg; Martillo cincel para corte-demolición; Autorización de centro de acopio para disposición final de residuos solidos (material desmonte no peligroso) [1 m3] | 3211.61h | 66,381.37 | 01.04.02.05 | 000000000001144 | 14 | 922.39 | 12913.46 | 1.75 |
| 31 | 1.4.2.6 | Demolición de buzón de mal estado, de 2,51 a 3,00 m de profundidad (incl. Eliminacion desmonte en centro acopio autorizado) | 45d | 2016-04-16 | 2016-05-31 | 30SS | 14d | 0d | start no earlier than 2015-09-30 | MO: Capataz incluye leyes sociales [9%]; MO: Operador de maquinaria-equipo pesado [123.6%]; MO: Operario incluye leyes sociales [88.9%]; MO: Oficial incluye leyes sociales [88.9%]; MO: Peon incluye leyes sociales [180.9%]; Camión volquete 4x2 210 - 280 HP 8m3 [10.9%]; Camioneta pick-up 4x2 simple 1000 kg 90 HP [22.2%]; Cargador sob. llanta 80-95HP 1 5-1 75 Yd3 [1.6%]; Compresora neumática 76 HP 125 - 175 pcm. [88.9%]; Martillo neumático 21 - 24 kg [88.9%]; Martillo cincel para corte-demolición [88.9%]; Autorización de centro de acopio para disposición final de residuos solidos (material desmonte no peligroso) [1 m3] | 2853.35h | 58,883.01 | 01.04.02.06 | 000000000001145 |  | 1072.89 | 4291.56 | 1.5 |
| 32 | 1.4.2.7 | Sellado de buzon existente con concreto fluido f'c=100kg/cm2 | 45d | 2016-04-18 | 2016-06-02 | 31SS+2d | 26d | 0d | start no earlier than 2015-09-30 | MO: Ingeniero residente incl. leyes sociales [2%]; MO: Técnico incluye leyes sociales [2%]; MO: Capataz incluye leyes sociales [2.4%]; MO: Operador de maquinaria-equipo pesado [17.1%]; MO: Operario incluye leyes sociales [13%]; MO: Oficial incluye leyes sociales [15.1%]; MO: Peon incluye leyes sociales [6.1%]; Camión concretero 6x4 235-300HP 8m3 [13%]; Cargador sob. llanta 80-95HP 1 5-1 75 Yd3 [2%]; Planta-Dosificadora de concreto PM (planta) [2%]; Arena gruesa [4.24 m3]; Piedra partida-grava de 1/2" - 3/4" [7.25 m3]; Agua incluye transporte a pie de obra (Camión cisterna y Motobomba) [1.71 m3]; Cemento portland I sector público; en bolsa [52.17 und] | 269.68h | 18,732.46 | 01.04.02.07 | 000000000001149 | 7.19 | 254.39 | 1829.06 | 9.7116 |
| 33 | 1.4.2.8 | buzon a anular, de 1.01 a 1.25 m de profundidad (inc. demolicion y eliminacion de losa) | 45d | 2016-04-18 | 2016-06-02 | 32SS | 26d | 0d | start no earlier than 2015-09-30 | MO: Capataz incluye leyes sociales [1.9%]; MO: Operador de maquinaria-equipo pesado [22.8%]; MO: Operario incluye leyes sociales [18.4%]; MO: Oficial incluye leyes sociales [8.8%]; MO: Peon incluye leyes sociales [98.4%]; Camión volquete 4x2 210 - 280 HP 8m3 [2.4%]; Camioneta pick-up 4x2 simple 1000 kg 90 HP [2.4%]; Mezcladora concreto t/tambor23HP 11-12p3 [0.4%]; Cargador sob. llanta 80-95HP 1 5-1 75 Yd3 [0.3%]; Compactadora vibrat. de plancha 7 HP [9.5%]; Compresora neumática 87 HP 250 - 330 pcm. [7.8%]; Martillo neumático 25 - 29 kg [15.7%]; Martillo cincel para corte-demolición [15.7%]; Vibrador de concreto 4 HP 18PL [0.6%]; Arena gruesa [0.04 m3]; Material granular S. A1a-A1b AASHTO [0.74 m3]; Piedra partida-grava de 1/2" - 3/4" [0.08 m3]; Agua incluye transporte a pie de obra (Camión cisterna y Motobomba) [0.29 m3]; Agua incluye transporte a pie de obra (Camión cisterna y Motobomba) [0.02 m3]; Autorización de centro de acopio para disposición final de residuos solidos (material desmonte no peligroso) [1 m3]; Madera para encofrado y carpintería [0.19 p2]; Cemento portland I sector público; en bolsa [0.77 und]; Sika:plastiment HE98 balde de 20 kg [0.01 und]; Regla de madera tipo tornillo especial [0.01 und] | 737.72h | 13,426.34 | 01.04.02.08 | 000000000001303 |  | 191.01 | 382.02 | 2.05 |
| 34 | 1.4.2.9 | buzon a anular, de 1.26 a 1.50 m de profundidad (inc. demolicion y eliminacion de losa) | 45d | 2016-04-18 | 2016-06-02 | 33SS | 26d | 0d | start no earlier than 2015-09-30 | MO: Capataz incluye leyes sociales [1%]; MO: Operador de maquinaria-equipo pesado [11.7%]; MO: Operario incluye leyes sociales [9.4%]; MO: Oficial incluye leyes sociales [4.5%]; MO: Peon incluye leyes sociales [50.4%]; Camión volquete 4x2 210 - 280 HP 8m3 [1.2%]; Camioneta pick-up 4x2 simple 1000 kg 90 HP [1.2%]; Mezcladora concreto t/tambor23HP 11-12p3 [0.2%]; Cargador sob. llanta 80-95HP 1 5-1 75 Yd3 [0.2%]; Compactadora vibrat. de plancha 7 HP [4.9%]; Compresora neumática 87 HP 250 - 330 pcm. [4%]; Martillo neumático 25 - 29 kg [8%]; Martillo cincel para corte-demolición [8%]; Vibrador de concreto 4 HP 18PL [0.3%]; Arena gruesa [0.02 m3]; Material granular S. A1a-A1b AASHTO [0.38 m3]; Piedra partida-grava de 1/2" - 3/4" [0.04 m3]; Agua incluye transporte a pie de obra (Camión cisterna y Motobomba) [0.15 m3]; Agua incluye transporte a pie de obra (Camión cisterna y Motobomba) [0.01 m3]; Autorización de centro de acopio para disposición final de residuos solidos (material desmonte no peligroso) [1 m3]; Madera para encofrado y carpintería [0.1 p2]; Cemento portland I sector público; en bolsa [0.39 und]; Sika:plastiment HE98 balde de 20 kg [0.01 und]; Regla de madera tipo tornillo especial [0 und] | 378.09h | 6,890.21 | 01.04.02.09 | 000000000001297 |  | 195.79 | 195.79 |  |
| 35 | 1.4.2.10 | buzon a anular, de 1.51 a 1.75 m de profundidad (inc. demolicion y eliminacion de losa) | 45d | 2016-04-18 | 2016-06-02 | 34SS | 26d | 0d | start no earlier than 2015-09-30 | MO: Capataz incluye leyes sociales [1%]; MO: Operador de maquinaria-equipo pesado [12.6%]; MO: Operario incluye leyes sociales [9.4%]; MO: Oficial incluye leyes sociales [4.5%]; MO: Peon incluye leyes sociales [53.9%]; Camión volquete 4x2 210 - 280 HP 8m3 [1.2%]; Camioneta pick-up 4x2 simple 1000 kg 90 HP [1.4%]; Mezcladora concreto t/tambor23HP 11-12p3 [0.2%]; Cargador sob. llanta 80-95HP 1 5-1 75 Yd3 [0.2%]; Compactadora vibrat. de plancha 7 HP [5.6%]; Compresora neumática 87 HP 250 - 330 pcm. [4%]; Martillo neumático 25 - 29 kg [8%]; Martillo cincel para corte-demolición [8%]; Vibrador de concreto 4 HP 18PL [0.3%]; Arena gruesa [0.02 m3]; Material granular S. A1a-A1b AASHTO [0.38 m3]; Piedra partida-grava de 1/2" - 3/4" [0.04 m3]; Agua incluye transporte a pie de obra (Camión cisterna y Motobomba) [0.16 m3]; Agua incluye transporte a pie de obra (Camión cisterna y Motobomba) [0.01 m3]; Autorización de centro de acopio para disposición final de residuos solidos (material desmonte no peligroso) [1 m3]; Madera para encofrado y carpintería [0.1 p2]; Cemento portland I sector público; en bolsa [0.39 und]; Sika:plastiment HE98 balde de 20 kg [0.01 und]; Regla de madera tipo tornillo especial [0 und] | 397.43h | 7,203.91 | 01.04.02.10 | 000000000001298 |  | 203.01 | 203.01 |  |
| 36 | 1.4.2.11 | buzon a anular, de 1.76 a 2.00 m de profundidad (inc. demolicion y eliminacion de losa) | 45d | 2016-04-18 | 2016-06-02 | 35SS | 26d | 0d | start no earlier than 2015-09-30 | MO: Capataz incluye leyes sociales [2.2%]; MO: Operador de maquinaria-equipo pesado [26.9%]; MO: Operario incluye leyes sociales [18.9%]; MO: Oficial incluye leyes sociales [9%]; MO: Peon incluye leyes sociales [115%]; Camión volquete 4x2 210 - 280 HP 8m3 [2.4%]; Camioneta pick-up 4x2 simple 1000 kg 90 HP [3.1%]; Mezcladora concreto t/tambor23HP 11-12p3 [0.4%]; Cargador sob. llanta 80-95HP 1 5-1 75 Yd3 [0.3%]; Compactadora vibrat. de plancha 7 HP [12.5%]; Compresora neumática 87 HP 250 - 330 pcm. [8%]; Martillo neumático 25 - 29 kg [16.1%]; Martillo cincel para corte-demolición [16.1%]; Vibrador de concreto 4 HP 18PL [0.6%]; Arena gruesa [0.04 m3]; Material granular S. A1a-A1b AASHTO [0.76 m3]; Piedra partida-grava de 1/2" - 3/4" [0.08 m3]; Agua incluye transporte a pie de obra (Camión cisterna y Motobomba) [0.35 m3]; Agua incluye transporte a pie de obra (Camión cisterna y Motobomba) [0.02 m3]; Autorización de centro de acopio para disposición final de residuos solidos (material desmonte no peligroso) [1 m3]; Madera para encofrado y carpintería [0.19 p2]; Cemento portland I sector público; en bolsa [0.79 und]; Sika:plastiment HE98 balde de 20 kg [0.01 und]; Regla de madera tipo tornillo especial [0.01 und] | 833.54h | 15,016.47 | 01.04.02.11 | 000000000001299 |  | 210.22 | 420.44 |  |
| 37 | 1.4.2.12 | buzon a anular, de 2.01 a 2.50 m de profundidad (inc. demolicion y eliminacion de losa) | 45d | 2016-04-18 | 2016-06-02 | 36SS | 26d | 0d | start no earlier than 2015-09-30 | MO: Capataz incluye leyes sociales [1.2%]; MO: Operador de maquinaria-equipo pesado [15.2%]; MO: Operario incluye leyes sociales [9.4%]; MO: Oficial incluye leyes sociales [4.5%]; MO: Peon incluye leyes sociales [64.5%]; Camión volquete 4x2 210 - 280 HP 8m3 [1.2%]; Camioneta pick-up 4x2 simple 1000 kg 90 HP [1.9%]; Mezcladora concreto t/tambor23HP 11-12p3 [0.2%]; Cargador sob. llanta 80-95HP 1 5-1 75 Yd3 [0.2%]; Compactadora vibrat. de plancha 7 HP [7.7%]; Compresora neumática 87 HP 250 - 330 pcm. [4%]; Martillo neumático 25 - 29 kg [8%]; Martillo cincel para corte-demolición [8%]; Vibrador de concreto 4 HP 18PL [0.3%]; Arena gruesa [0.02 m3]; Material granular S. A1a-A1b AASHTO [0.38 m3]; Piedra partida-grava de 1/2" - 3/4" [0.04 m3]; Agua incluye transporte a pie de obra (Camión cisterna y Motobomba) [0.2 m3]; Agua incluye transporte a pie de obra (Camión cisterna y Motobomba) [0.01 m3]; Autorización de centro de acopio para disposición final de residuos solidos (material desmonte no peligroso) [1 m3]; Madera para encofrado y carpintería [0.1 p2]; Cemento portland I sector público; en bolsa [0.39 und]; Sika:plastiment HE98 balde de 20 kg [0.01 und]; Regla de madera tipo tornillo especial [0 und] | 455.44h | 8,144.93 | 01.04.02.12 | 000000000001300 |  | 224.66 | 224.66 |  |
| 38 | 1.4.2.13 | Sellado de tuberia existente CSN DN 250 | 45d | 2016-04-20 | 2016-06-04 | 37SS+2d | 26d |  | start no earlier than 2015-09-30 | MO: Ingeniero residente incl. leyes sociales [17.1%]; MO: Técnico incluye leyes sociales [17.1%]; MO: Capataz incluye leyes sociales [19.8%]; MO: Operador de maquinaria-equipo pesado [143.6%]; MO: Operario incluye leyes sociales [109.4%]; MO: Oficial incluye leyes sociales [126.5%]; MO: Peon incluye leyes sociales [51.3%]; Camión concretero 6x4 235-300HP 8m3 [109.4%]; Cargador sob. llanta 80-95HP 1 5-1 75 Yd3 [17.1%]; Planta-Dosificadora de concreto PM (planta) [17.1%]; Arena gruesa [35.56 m3]; Piedra partida-grava de 1/2" - 3/4" [60.86 m3]; Agua incluye transporte a pie de obra (Camión cisterna y Motobomba) [14.36 m3]; Cemento portland I sector público; en bolsa [437.66 und] | 2262.43h | 157,152.99 | 01.04.02.13 | 000000000001155 | 931.67 | 16.47 | 15344.6 | 985.4223 |
| 39 | 1.5 | **MOVIMIENTO DE TIERRAS** | 66d | 2016-04-15 | 2016-06-20 |  | 0d |  |  |  | 320063h | 8,894,484.12 | 01.05 | 000000000001157 |  |  |  |  |
| 40 | 1.5.1 | **EXCAVACION CON EQUIPO** | 66d | 2016-04-15 | 2016-06-20 |  | 0d |  |  |  | 60164.9h | 1,825,512.05 | 01.05.01 | 000000000001158 |  |  |  |  |
| 41 | 1.5.1.1 | Excavac. zanja (máq.) p/tub. terr-normal DN 200 - 250 de 1,01 m a 1,25 m prof. | 60d | 2016-04-15 | 2016-06-14 | 15 | 0d |  | start no earlier than 2015-09-30 | MO: Capataz incluye leyes sociales [1.8%]; MO: Operador de maquinaria-equipo pesado [18.1%]; MO: Oficial incluye leyes sociales [18.1%]; MO: Peon incluye leyes sociales [18.1%]; Cargador retroexcava dor 0 5-0 75Yd3 62HP [18.1%] | 356.78h | 14,063.73 | 01.05.01.01 | 000000000001159 | 30.4 | 7.76 | 235.9 | 167.6 |
| 42 | 1.5.1.2 | Excavac. zanja (máq.) p/tub. terr-normal DN 200 - 250 de 1,26 m a 1,50 m prof. | 60d | 2016-04-15 | 2016-06-14 | 41SS | 14d | 0d | start no earlier than 2015-09-30 | MO: Capataz incluye leyes sociales [7.3%]; MO: Operador de maquinaria-equipo pesado [72.8%]; MO: Oficial incluye leyes sociales [72.8%]; MO: Peon incluye leyes sociales [145.6%]; Cargador retroexcava dor 0 5-0 75Yd3 62HP [72.8%] | 1782.52h | 61,536.02 | 01.05.01.02 | 000000000001160 | 207.39 | 9.97 | 2067.68 | 142.45 |
| 43 | 1.5.1.3 | Excavac. zanja (máq.) p/tub. terr-normal DN 200 - 250 de 1,51 m a 1,75 m prof. | 60d | 2016-04-15 | 2016-06-14 | 42SS | 14d | 0d | start no earlier than 2015-09-30 | MO: Capataz incluye leyes sociales [9.3%]; MO: Operador de maquinaria-equipo pesado [92.5%]; MO: Oficial incluye leyes sociales [92.5%]; MO: Peon incluye leyes sociales [92.5%]; Cargador retroexcava dor 0 5-0 75Yd3 62HP [92.5%] | 1820.12h | 71,749.36 | 01.05.01.03 | 000000000001161 | 456 | 10.56 | 4815.36 | 123.34 |
| 44 | 1.5.1.4 | Excavac. zanja (máq.) p/tub. terr-normal DN 200 - 250 de 1,76 m a 2,00 m prof. | 60d | 2016-04-15 | 2016-06-14 | 43SS | 14d | 0d | start no earlier than 2015-09-30 | MO: Capataz incluye leyes sociales [8.8%]; MO: Operador de maquinaria-equipo pesado [88.5%]; MO: Oficial incluye leyes sociales [88.5%]; MO: Peon incluye leyes sociales [88.5%]; Cargador retroexcava dor 0 5-0 75Yd3 62HP [88.5%] | 1741.94h | 68,668.95 | 01.05.01.04 | 000000000001162 | 744.42 | 12.38 | 9215.92 | 105.15 |
| 45 | 1.5.1.5 | Excavac. zanja (máq.) p/tub. terr-normal DN 200 - 250 de 2,01 m a 2,50 m prof. | 60d | 2016-04-15 | 2016-06-14 | 44SS | 14d | 0d | start no earlier than 2015-09-30 | MO: Capataz incluye leyes sociales [6%]; MO: Operador de maquinaria-equipo pesado [59.6%]; MO: Oficial incluye leyes sociales [59.6%]; MO: Peon incluye leyes sociales [59.6%]; Cargador retroexcava dor 0 5-0 75Yd3 62HP [59.6%] | 1173.41h | 46,256.31 | 01.05.01.05 | 000000000001163 | 100.42 | 15.45 | 1551.49 | 84.18 |
| 46 | 1.5.1.6 | Excavac. zanja (máq.) p/tub. terr-normal DN 300 - 350 de 2,01 m a 2,50 m prof. | 60d | 2016-04-15 | 2016-06-14 | 41SS | 10d | 0d | start no earlier than 2015-09-30 | MO: Capataz incluye leyes sociales [7%]; MO: Operador de maquinaria-equipo pesado [70.4%]; MO: Oficial incluye leyes sociales [70.4%]; MO: Peon incluye leyes sociales [70.4%]; Cargador retroexcava dor 0 5-0 75Yd3 62HP [70.4%] | 1384.96h | 54,595.63 | 01.05.01.06 | 000000000001304 | 47.31 | 19.36 | 915.92 | 67.21 |
| 47 | 1.5.1.7 | Excavac. zanja (máq.) p/tub. terr-normal DN 300 - 350 de 2,51 m a 3,00 m prof. | 60d | 2016-04-15 | 2016-06-14 | 46SS | 10d | 0d | start no earlier than 2015-09-30 | MO: Capataz incluye leyes sociales [10%]; MO: Operador de maquinaria-equipo pesado; MO: Oficial incluye leyes sociales; MO: Peon incluye leyes sociales; Cargador retroexcava dor 0 5-0 75Yd3 62HP | 1960.78h | 77,294.35 | 01.05.01.07 | 000000000001305 | 54.63 | 23.75 | 1297.46 | 54.84 |
| 48 | 1.5.1.8 | Entibado de madera para linea hasta 2.00 m de prof. | 60d | 2016-04-15 | 2016-06-14 | 44SS | 16d |  | start no earlier than 2015-09-30 | MO: Capataz incluye leyes sociales [39.4%]; MO: Operario incluye leyes sociales [393.9%]; MO: Peon incluye leyes sociales [787.7%]; Clavo c/cabeza para madera (promedio) [1530.53 kg]; Madera para encofrado y carpintería [5907.72 p2] | 5860.74h | 123,200.96 | 01.05.01.08 | 000000000001164 | 744.42 | 95.64 | 71196.33 | 28 |
| 49 | 1.5.1.9 | Entibado de madera para linea hasta 3.00 m de prof. | 60d | 2016-04-15 | 2016-06-14 | 47SS | 16d |  | start no earlier than 2015-09-30 | MO: Capataz incluye leyes sociales [38.5%]; MO: Operario incluye leyes sociales [385%]; MO: Peon incluye leyes sociales [770%]; Clavo c/cabeza para madera (promedio) [443.3 kg]; Madera para encofrado y carpintería [1711.11 p2] | 5729.06h | 101,821.09 | 01.05.01.09 | 000000000001165 | 202.93 | 101.62 | 20621.75 | 28 |
| 50 | 1.5.1.10 | Refine y nivel de zanja terr-normal para tub. DN 200 - 250 para toda profund. | 59d | 2016-04-16 | 2016-06-14 | 41SS+1d | 16d |  | start no earlier than 2015-09-30 | MO: Capataz incluye leyes sociales [10.1%]; MO: Peon incluye leyes sociales [199.1%] | 987.35h | 14,841.22 | 01.05.01.10 | 000000000001166 | 1517.2 | 1.69 | 2564.07 | 152.38 |
| 51 | 1.5.1.11 | Refine y nivel de zanja terr-normal para tub. DN 300 - 350 para toda profund. | 59d | 2016-04-16 | 2016-06-14 | 47SS+1d | 16d |  | start no earlier than 2015-09-30 | MO: Capataz incluye leyes sociales [8.5%]; MO: Peon incluye leyes sociales [169.9%] | 842.02h | 12,654.65 | 01.05.01.11 | 000000000001306 | 101.94 | 2.14 | 218.15 | 120 |
| 52 | 1.5.1.12 | Relleno comp. zanja(pulso) p/tub t-normal DN 200 - 250 de 1.01 m a 1.25 m prof. | 57d | 2016-04-20 | 2016-06-16 | 41SS+5d | 0d |  | start no earlier than 2015-09-30 | MO: Capataz incluye leyes sociales [9.3%]; MO: Operador de maquinaria-equipo pesado [42.9%]; MO: Peon incluye leyes sociales [415.6%]; Compactadora vibrat. de plancha 7 HP [42.9%]; Arena gruesa [2.34 m3]; Agua incluye transporte a pie de obra (Camión cisterna y Motobomba) [1.73 m3] | 2328.76h | 35,097 | 01.05.01.12 | 000000000001167 | 30.4 | 24.77 | 753.01 | 70.95 |
| 53 | 1.5.1.13 | Relleno comp.zanja(pulso) p/tub t-normal DN 200 - 250 de 1,26 m a 1,50 m prof. | 57d | 2016-04-20 | 2016-06-16 | 42SS+5d | 14d |  | start no earlier than 2015-09-30 | MO: Capataz incluye leyes sociales [21.2%]; MO: Operador de maquinaria-equipo pesado [97.3%]; MO: Peon incluye leyes sociales [944.5%]; Compactadora vibrat. de plancha 7 HP [97.3%]; Arena gruesa [15.97 m3]; Agua incluye transporte a pie de obra (Camión cisterna y Motobomba) [10.16 m3] | 5290.89h | 80,307.08 | 01.05.01.13 | 000000000001168 | 207.39 | 24.68 | 5118.39 | 71.05 |
| 54 | 1.5.1.14 | Relleno comp.zanja(pulso) p/tub t-normal DN 200 - 250 de 1,51 m a 1,75 m prof. | 57d | 2016-04-20 | 2016-06-16 | 43SS+5d | 14d |  | start no earlier than 2015-09-30 | MO: Capataz incluye leyes sociales [17.6%]; MO: Operador de maquinaria-equipo pesado [91.8%]; MO: Peon incluye leyes sociales [794.8%]; Compactadora vibrat. de plancha 7 HP [91.8%]; Arena gruesa [35.11 m3]; Agua incluye transporte a pie de obra (Camión cisterna y Motobomba) [25.99 m3] | 4542.04h | 70,261.39 | 01.05.01.14 | 000000000001169 | 456 | 28.33 | 12918.48 | 55.17 |
| 55 | 1.5.1.15 | Relleno comp.zanja(pulso) p/tub t-normal DN 200 - 250 de 1,76 m a 2,00 m prof. | 57d | 2016-04-20 | 2016-06-16 | 44SS+5d | 14d |  | start no earlier than 2015-09-30 | MO: Capataz incluye leyes sociales [16.5%]; MO: Operador de maquinaria-equipo pesado [96.4%]; MO: Peon incluye leyes sociales [756.1%]; Compactadora vibrat. de plancha 7 HP [96.4%]; Arena gruesa [57.32 m3]; Agua incluye transporte a pie de obra (Camión cisterna y Motobomba) [49.88 m3] | 4402.38h | 69,574.04 | 01.05.01.15 | 000000000001170 | 744.42 | 32.97 | 24543.53 | 42.89 |
| 56 | 1.5.1.16 | Relleno comp.zanja(pulso) p/tub t-normal DN 200 - 250 de 2,01 m a 2,50 m prof. | 57d | 2016-04-20 | 2016-06-16 | 45SS+5d | 14d |  | start no earlier than 2015-09-30 | MO: Capataz incluye leyes sociales [12.3%]; MO: Operador de maquinaria-equipo pesado [81.2%]; MO: Peon incluye leyes sociales [573.4%]; Compactadora vibrat. de plancha 7 HP [81.2%]; Arena gruesa [7.78 m3]; Agua incluye transporte a pie de obra (Camión cisterna y Motobomba) [8.58 m3] | 3411.73h | 51,979.83 | 01.05.01.16 | 000000000001171 | 100.99 | 40.96 | 4136.55 | 31.08 |
| 57 | 1.5.1.17 | Relleno comp.zanja (máq) p/tub. t-normal DN 300 - 350 de 2,01 m a 2,50 m prof. | 57d | 2016-04-20 | 2016-06-16 | 46SS+5d | 14d |  | start no earlier than 2015-09-30 | MO: Capataz incluye leyes sociales [12.9%]; MO: Operador de maquinaria-equipo pesado [65.8%]; MO: Peon incluye leyes sociales [495.9%]; Cargador sob. llanta 80-95HP 1 5-1 75 Yd3 [21.9%]; Compactadora vibrat. de plancha 7 HP [21.9%]; Rodillo liso vibrat. 0 8-1 1 ton manual ó de control remoto [21.9%]; Arena gruesa [3.43 m3]; Agua incluye transporte a pie de obra (Camión cisterna y Motobomba) [4.87 m3] | 2920.73h | 55,840.05 | 01.05.01.17 | 000000000001308 | 47.31 | 25.41 | 1202.15 | 215.68 |
| 58 | 1.5.1.18 | Relleno comp.zanja (máq) p/tub. t-normal DN 300 - 350 de 2,51 m a 3,00 m prof. | 57d | 2016-04-20 | 2016-06-16 | 47SS+5d | 10d | 0d | start no earlier than 2015-09-30 | MO: Capataz incluye leyes sociales [16.2%]; MO: Operador de maquinaria-equipo pesado [101.7%]; MO: Peon incluye leyes sociales [615.2%]; Cargador sob. llanta 80-95HP 1 5-1 75 Yd3 [33.9%]; Compactadora vibrat. de plancha 7 HP [33.9%]; Rodillo liso vibrat. 0 8-1 1 ton manual ó de control remoto [33.9%]; Arena gruesa [5.29 m3]; Agua incluye transporte a pie de obra (Camión cisterna y Motobomba) [6.99 m3] | 3806.33h | 75,859.42 | 01.05.01.18 | 000000000001309 | 54.63 | 30.47 | 1664.58 | 161.21 |
| 59 | 1.5.1.19 | Elimin. desmonte(carg+v) t-normal D=20km p/tub. DN 200 - 250 para toda prof. | 59d | 2016-04-22 | 2016-06-20 | 52SS+2d | 0d |  | start no earlier than 2015-09-30 | MO: Capataz incluye leyes sociales [7.7%]; MO: Operador de maquinaria-equipo pesado [592.6%]; MO: Peon incluye leyes sociales [296.3%]; Camión volquete 4x2 210 - 280 HP 8m3 [517.6%]; Cargador sob. llanta 80-95HP 1 5-1 75 Yd3 [73.1%]; Autorizacion de centro de acopio para disposicion final de residuos peligrosos [1 m3] | 7019.84h | 567,450.4 | 01.05.01.19 | 000000000001172 | 1539.2 | 9.37 | 14422.3 | 2080.92 |
| 60 | 1.5.1.20 | Elimin. desmonte(carg+v) t-normal D=20km p/tub. DN 300 - 350 para toda prof. | 59d | 2016-04-22 | 2016-06-20 | 58SS+2d | 10d |  | start no earlier than 2015-09-30 | MO: Capataz incluye leyes sociales [0.9%]; MO: Operador de maquinaria-equipo pesado [67.8%]; MO: Peon incluye leyes sociales [33.9%]; Camión volquete 4x2 210 - 280 HP 8m3 [59.3%]; Cargador sob. llanta 80-95HP 1 5-1 75 Yd3 [8.4%]; Autorizacion de centro de acopio para disposicion final de residuos peligrosos [1 m3] | 803.53h | 64,998.64 | 01.05.01.20 | 000000000001310 | 101.94 | 16.21 | 1652.45 | 1204.01 |
| 61 | 1.5.1.21 | Desmontaje y retiro de tuberia CSN DN 200 - 250 mm | 58d | 2016-04-17 | 2016-06-14 | 41SS+2d | 16d |  | start no earlier than 2015-09-30 | MO: Capataz incluye leyes sociales [10%]; MO: Operario incluye leyes sociales; MO: Peon incluye leyes sociales | 973.28h | 16,897.37 | 01.05.01.21 | 000000000001173 | 1796.65 | 2.55 | 4581.46 | 120 |
| 62 | 1.5.1.22 | Desmontaje y retiro de tuberia CSN DN 300 - 350 mm | 58d | 2016-04-17 | 2016-06-14 | 47SS+2d | 16d | 0d | finish no earlier than 2015-11-29 |  |  |  | 01.05.01.22 |  |  |  |  |  |
| 63 | 1.5.1.23 | Eliminación de desmonte en terreno normal R=20 km con maquinaria (incluye pago por disposicion final material peligroso) | 60d | 2016-04-18 | 2016-06-17 | 62SS+1d | 13d |  | start no earlier than 2015-09-30 | MO: Capataz incluye leyes sociales [1.2%]; MO: Operador de maquinaria-equipo pesado [94.4%]; MO: Peon incluye leyes sociales [23.6%]; Camión volquete 4x2 210 - 280 HP 8m3 [82.6%]; Cargador sob. llanta 80-95HP 1 5-1 75 Yd3 [11.8%]; Autorización de centro de acopio para disposición final de residuos solidos (Tuberias de concreto p/desague) [1 m3] | 1025.71h | 90,564.55 | 01.05.01.23 | 000000000001311 | 34 | 68.79 | 2338.86 | 288 |

| ID | WBS | Task | Duration | Start | Finish | Predecessors | Total slack | Free slack | Constraint | Resources | Work | Cost | Text1 | Text8 | Text2 | Text3 | Text4 | Text6 |
| --- | --- | --- | --- | --- | --- | --- | --- | --- | --- | --- | --- | --- | --- | --- | --- | --- | --- | --- |
| 64 | 1.5.2 | **EXCAVACION A MANO EN PASAJES ANGOSTOS CON INTERFERENCIAS** | 64d | 2016-04-16 | 2016-06-19 |  | 11d |  |  |  | 70003.4h | 1,684,291.41 | 01.05.02 | 000000000001176 |  |  |  |  |
| 65 | 1.5.2.1 | Proteccion de redes existentes | 60d | 2016-04-16 | 2016-06-15 | 41SS+1d | 11d | 0d | start no earlier than 2015-09-30 | MO: Capataz incluye leyes sociales [9.9%]; MO: Operario incluye leyes sociales [98.5%]; MO: Peon incluye leyes sociales [98.5%]; Alambre negro N° 8 [260.15 kg]; Clavo c/cabeza para madera (promedio) [2.37 kg]; Madera para encofrado y carpintería [157.51 p2] | 993.37h | 18,424.77 | 01.05.02.01 | 000000000001177 | 473 | 27.31 | 12917.63 | 12 |
| 66 | 1.5.2.2 | Proteccion de postes para alumbrado - telefono | 60d | 2016-04-16 | 2016-06-15 | 65SS | 11d | 0d | start no earlier than 2015-09-30 | MO: Capataz incluye leyes sociales [9.7%]; MO: Operario incluye leyes sociales [97.3%]; MO: Oficial incluye leyes sociales [97.3%]; MO: Peon incluye leyes sociales [194.6%]; Alambre negro N° 8 [268.5 kg]; Clavo c/cabeza para madera (promedio) [17.9 kg]; Madera para encofrado y carpintería [3311.5 p2] | 1914.52h | 44,453.54 | 01.05.02.02 | 000000000001178 | 179 | 142.12 | 25439.48 |  |
| 67 | 1.5.2.3 | Excav. zanja (pulso) p/tub. terr-normal DN 200 - 250 de 1,26 m a 1,50 m prof. | 60d | 2016-04-16 | 2016-06-15 | 66SS | 11d | 0d | start no earlier than 2015-09-30 | MO: Capataz incluye leyes sociales [9.7%]; MO: Peon incluye leyes sociales [972.7%] | 4715.52h | 68,516.81 | 01.05.02.03 | 000000000001179 | 325.46 | 35.79 | 11648.21 | 33.46 |
| 68 | 1.5.2.4 | Excav. zanja (pulso) p/tub. terr-normal DN 200 - 250 de 1,51 m a 1,75 m prof. | 60d | 2016-04-16 | 2016-06-15 | 67SS | 13d | 0d | start no earlier than 2015-09-30 | MO: Capataz incluye leyes sociales [9.9%]; MO: Peon incluye leyes sociales [992.7%] | 4812.7h | 69,928.63 | 01.05.02.04 | 000000000001180 | 419.04 | 48.24 | 20214.49 | 24.83 |
| 69 | 1.5.2.5 | Excav. zanja (pulso) p/tub. terr-normal DN 200 - 250 de 1,76 m a 2,00 m prof. | 60d | 2016-04-16 | 2016-06-15 | 67SS | 11d | 0d | start no earlier than 2015-09-30 | MO: Capataz incluye leyes sociales [10%]; MO: Peon incluye leyes sociales [999.3%] | 4844.61h | 70,392.61 | 01.05.02.05 | 000000000001181 | 499.65 | 47.9 | 23933.24 | 25 |
| 70 | 1.5.2.6 | Excav. zanja (pulso) p/tub. terr-normal DN 200 - 250 de 2,01 m a 2,50 m prof. | 60d | 2016-04-16 | 2016-06-15 | 69SS | 11d | 0d | start no earlier than 2015-09-30 | MO: Capataz incluye leyes sociales [9.9%]; MO: Peon incluye leyes sociales [990.8%] | 4803.55h | 69,796.59 | 01.05.02.06 | 000000000001313 | 559.62 | 84.81 | 47461.37 | 14.12 |
| 71 | 1.5.2.7 | Excav. zanja (pulso) p/tub. terr-normal DN 200 - 250 de 2,51 m a 3,00 m prof. | 60d | 2016-04-16 | 2016-06-15 | 70SS | 11d | 0d | start no earlier than 2015-09-30 | MO: Capataz incluye leyes sociales [9.8%]; MO: Peon incluye leyes sociales [981.2%] | 4757.09h | 69,121.17 | 01.05.02.07 | 000000000001182 | 89.49 | 105.04 | 9400.03 | 11.4 |
| 72 | 1.5.2.8 | Excav. zanja (pulso) p/tub. terr-normal DN 300 - 350 de 2,01 m a 2,50 m prof. | 60d | 2016-04-16 | 2016-06-15 | 70SS | 11d | 0d | start no earlier than 2015-09-30 | MO: Capataz incluye leyes sociales [7.6%]; MO: Peon incluye leyes sociales [760.4%] | 3686.49h | 53,564.92 | 01.05.02.08 | 000000000001314 | 34.31 | 106.16 | 3642.35 | 11.28 |
| 73 | 1.5.2.9 | Entibado de madera para linea hasta 2.00 m de prof. | 60d | 2016-04-16 | 2016-06-15 | 69SS | 15d |  | finish no earlier than 2015-11-16 |  |  |  | 01.05.02.09 |  |  |  |  |  |
| 74 | 1.5.2.10 | Entibado de madera para linea hasta 3.00 m de prof. | 60d | 2016-04-16 | 2016-06-15 | 71SS | 15d |  | finish no earlier than 2015-11-04 |  |  |  | 01.05.02.10 |  |  |  |  |  |
| 75 | 1.5.2.11 | Refine y nivel de zanja terr-normal para tub. DN 200 - 250 para toda profund. | 60d | 2016-04-17 | 2016-06-16 | 71SS+1d | 14d |  | start no earlier than 2015-09-30 | MO: Capataz incluye leyes sociales [9.6%]; MO: Peon incluye leyes sociales [191.1%] | 963.82h | 14,487.48 | 01.05.02.11 | 000000000001187 | 1893.26 | 1.69 | 3199.61 | 152.38 |
| 76 | 1.5.2.12 | Refine y nivel de zanja terr-normal para tub. DN 300 - 350 para toda profund. | 60d | 2016-04-17 | 2016-06-16 | 72SS+1d | 14d |  | start no earlier than 2015-09-30 | MO: Capataz incluye leyes sociales [2.7%]; MO: Peon incluye leyes sociales [54.5%] | 274.62h | 4,127.66 | 01.05.02.12 | 000000000001188 | 34.31 | 2.05 | 70.34 | 125.98 |
| 77 | 1.5.2.13 | Relleno comp.zanja(pulso) p/tub t-normal DN 200 - 250 de 1,26 m a 1,50 m prof. | 60d | 2016-04-18 | 2016-06-17 | 67SS+2d | 13d |  | start no earlier than 2015-09-30 | MO: Capataz incluye leyes sociales [20%]; MO: Operador de maquinaria-equipo pesado [91.6%]; MO: Peon incluye leyes sociales [889.3%]; Compactadora vibrat. de plancha 7 HP [91.6%]; Arena gruesa [25.06 m3]; Agua incluye transporte a pie de obra (Camión cisterna y Motobomba) [15.95 m3] | 5244.05h | 80,093.3 | 01.05.02.13 | 000000000001189 | 325.46 | 24.68 | 8032.35 | 71.05 |
| 78 | 1.5.2.14 | Relleno comp.zanja(pulso) p/tub t-normal DN 200 - 250 de 1,51 m a 1,75 m prof. | 60d | 2016-04-18 | 2016-06-17 | 68SS+2d | 13d |  | start no earlier than 2015-09-30 | MO: Capataz incluye leyes sociales [18.2%]; MO: Operador de maquinaria-equipo pesado [94.9%]; MO: Peon incluye leyes sociales [821.7%]; Compactadora vibrat. de plancha 7 HP [94.9%]; Arena gruesa [32.27 m3]; Agua incluye transporte a pie de obra (Camión cisterna y Motobomba) [23.89 m3] | 4942.77h | 76,134.06 | 01.05.02.14 | 000000000001190 | 419.04 | 28.33 | 11871.4 | 55.17 |
| 79 | 1.5.2.15 | Relleno comp.zanja(pulso) p/tub t-normal DN 200 - 250 de 1,76 m a 2,00 m prof. | 60d | 2016-04-18 | 2016-06-17 | 69SS+2d | 13d |  | start no earlier than 2015-09-30 | MO: Capataz incluye leyes sociales [16.6%]; MO: Operador de maquinaria-equipo pesado [97.1%]; MO: Peon incluye leyes sociales [761.2%]; Compactadora vibrat. de plancha 7 HP [97.1%]; Arena gruesa [38.47 m3]; Agua incluye transporte a pie de obra (Camión cisterna y Motobomba) [33.48 m3] | 4665.55h | 72,481.54 | 01.05.02.15 | 000000000001191 | 499.65 | 32.97 | 16473.46 | 42.89 |
| 80 | 1.5.2.16 | Relleno comp.zanja(pulso) p/tub t-normal DN 200 - 250 de 2,01 m a 2,50 m prof. | 60d | 2016-04-18 | 2016-06-17 | 70SS+2d | 13d |  | start no earlier than 2015-09-30 | MO: Capataz incluye leyes sociales [14.3%]; MO: Operador de maquinaria-equipo pesado [94.8%]; MO: Peon incluye leyes sociales [669%]; Compactadora vibrat. de plancha 7 HP [94.8%]; Arena gruesa [43.09 m3]; Agua incluye transporte a pie de obra (Camión cisterna y Motobomba) [47.57 m3] | 4189.6h | 65,794.35 | 01.05.02.16 | 000000000001315 | 559.62 | 40.96 | 22922.04 | 31.08 |
| 81 | 1.5.2.17 | Relleno comp.zanja(pulso) p/tub t-normal DN 200 - 250 de 2,51 m a 3,00 m prof. | 60d | 2016-04-18 | 2016-06-17 | 71SS+2d | 11d | 0d | start no earlier than 2015-09-30 | MO: Capataz incluye leyes sociales [13.3%]; MO: Operador de maquinaria-equipo pesado [95.6%]; MO: Peon incluye leyes sociales [626.5%]; Compactadora vibrat. de plancha 7 HP [95.6%]; Arena gruesa [6.89 m3]; Agua incluye transporte a pie de obra (Camión cisterna y Motobomba) [9.49 m3] | 3988.83h | 60,754.67 | 01.05.02.17 | 000000000001192 | 89.49 | 50.47 | 4516.56 | 23.39 |
| 82 | 1.5.2.18 | Relleno comp.zanja(pulso) p/tub t-normal DN 300 - 350 de 2,01 m a 2,50 m prof. | 60d | 2016-04-18 | 2016-06-17 | 72SS+2d | 11d | 0d | start no earlier than 2015-09-30 | MO: Capataz incluye leyes sociales [13.3%]; MO: Operador de maquinaria-equipo pesado [95.6%]; MO: Peon incluye leyes sociales [626.5%]; Compactadora vibrat. de plancha 7 HP [95.6%]; Arena gruesa [6.88 m3]; Agua incluye transporte a pie de obra (Camión cisterna y Motobomba) [9.48 m3] | 3988.83h | 60,754.3 | 01.05.02.18 | 000000000001192 | 89.49 | 50.47 | 4516.56 | 23.39 |
| 83 | 1.5.2.19 | Acarreo de desmonte (pulso) p/tub.DN 200 - 250 mm t. normal en zona aledaña durante la excavación | 61d | 2016-04-16 | 2016-06-16 | 71SS | 14d |  | start no earlier than 2015-09-30 | MO: Capataz incluye leyes sociales [9.9%]; MO: Peon incluye leyes sociales [99.4%] | 533.77h | 8,323.93 | 01.05.02.19 | 000000000001194 | 1893.26 | 8.75 | 16566.03 | 16 |
| 84 | 1.5.2.20 | Acarreo de desmonte (pulso) p/tub.DN 200 - 250 mm t. normal en zona aledaña para el relleno | 61d | 2016-04-18 | 2016-06-18 | 81SS | 11d | 0d | start no earlier than 2015-09-30 | MO: Capataz incluye leyes sociales [9.9%]; MO: Peon incluye leyes sociales [99.4%] | 533.77h | 8,323.93 | 01.05.02.20 | 000000000001195 | 1893.26 | 8.75 | 16566.03 | 16 |
| 85 | 1.5.2.21 | Acarreo de desmonte (pulso) p/tub.DN 300 - 350 mm t. normal en zona aledaña durante la excavación | 61d | 2016-04-16 | 2016-06-16 | 72SS | 14d |  | start no earlier than 2015-09-30 | MO: Capataz incluye leyes sociales [7.4%]; MO: Peon incluye leyes sociales [73.8%] | 396.05h | 6,176.12 | 01.05.02.21 | 000000000001196 | 34.31 | 9.03 | 309.82 | 15.5 |
| 86 | 1.5.2.22 | Acarreo de desmonte (pulso) p/tub.DN 300 - 350 mm t. normal en zona aledaña para el relleno | 61d | 2016-04-18 | 2016-06-18 | 82SS | 11d | 0d | start no earlier than 2015-09-30 | MO: Capataz incluye leyes sociales [7.4%]; MO: Peon incluye leyes sociales [73.8%] | 396.05h | 6,176.12 | 01.05.02.22 | 000000000001197 | 34.31 | 9.03 | 309.82 | 15.5 |
| 87 | 1.5.2.23 | Desmontaje y retiro de tuberia CSN DN 200 - 250 mm | 58d | 2016-04-18 | 2016-06-15 | 71SS+2d | 15d |  | finish no earlier than 2015-11-26 |  |  |  | 01.05.02.23 |  |  |  |  |  |
| 88 | 1.5.2.24 | Desmontaje y retiro de tuberia CSN DN 300 - 350 mm | 58d | 2016-04-18 | 2016-06-15 | 72SS+2d | 15d |  | finish no earlier than 2015-12-03 |  |  |  | 01.05.02.24 |  |  |  |  |  |
| 89 | 1.5.2.25 | Elimin. desmonte(carg+v) t-normal D=20km p/tub. DN 200 - 250 para toda prof. | 62d | 2016-04-18 | 2016-06-19 | 84SS | 11d |  | start no earlier than 2015-09-30 | MO: Capataz incluye leyes sociales [9.5%]; MO: Operador de maquinaria-equipo pesado [728.9%]; MO: Peon incluye leyes sociales [364.5%]; Camión volquete 4x2 210 - 280 HP 8m3 [636.6%]; Cargador sob. llanta 80-95HP 1 5-1 75 Yd3 [89.9%]; Autorizacion de centro de acopio para disposicion final de residuos peligrosos [1 m3] | 9073.64h | 733,464.82 | 01.05.02.25 | 000000000001198 | 1893.26 | 9.37 | 17739.85 | 2080.92 |
| 90 | 1.5.2.26 | Elimin. desmonte(carg+v) t-normal D=20km p/tub. DN 300 - 350 para toda prof. | 62d | 2016-04-18 | 2016-06-19 | 86SS | 11d |  | start no earlier than 2015-09-30 | MO: Capataz incluye leyes sociales [0.3%]; MO: Operador de maquinaria-equipo pesado [22.8%]; MO: Peon incluye leyes sociales [11.4%]; Camión volquete 4x2 210 - 280 HP 8m3 [19.9%]; Cargador sob. llanta 80-95HP 1 5-1 75 Yd3 [2.8%]; Autorizacion de centro de acopio para disposicion final de residuos peligrosos [1 m3] | 284.19h | 23,000.07 | 01.05.02.26 | 000000000001199 | 34.31 | 16.21 | 556.17 | 1204.01 |

| ID | WBS | Task | Duration | Start | Finish | Predecessors | Total slack | Free slack | Constraint | Resources | Work | Cost | Text1 | Text8 | Text2 | Text3 | Text4 | Text6 |
| --- | --- | --- | --- | --- | --- | --- | --- | --- | --- | --- | --- | --- | --- | --- | --- | --- | --- | --- |
| 91 | 1.5.3 | **RETIRO Y REPOSICION DE CAJAS DE AGUA POR INTERFERENCIA CON LA EXCAVACION EN PASAJES ANGOSTOS** | 55d | 2016-04-15 | 2016-06-09 |  | 21d |  |  |  | 189895h | 5,384,680.67 | 01.05.03 | 000000000001200 |  |  |  |  |
| 92 | 1.5.3.1 | Demolición de caja y tapa en mal estado, de conex. dom. agua (incl. acomodo del desmonte para su eliminación) | 45d | 2016-04-15 | 2016-05-30 | 15 | 25d | 0d | start no earlier than 2015-09-30 | MO: Capataz incluye leyes sociales [9.7%]; MO: Peon incluye leyes sociales [193.5%] | 731.25h | 10,987.1 | 01.05.03.01 | 000000000001201 | 325 | 10.73 | 3487.25 | 24 |
| 93 | 1.5.3.2 | Acarreo de desmonte producto de la demolicion | 45d | 2016-04-16 | 2016-05-31 | 92SS+1d | 25d | 0d | start no earlier than 2015-09-30 | MO: Capataz incluye leyes sociales [6.1%]; MO: Peon incluye leyes sociales [302.9%] | 1112.24h | 16,302.92 | 01.05.03.02 | 000000000001202 | 15.69 | 47.1 | 739 | 12.95 |
| 94 | 1.5.3.3 | Eliminación de desmonte en terreno normal R=20 km con maquinaria (incluye pago por disposicion final material peligroso) | 50d | 2016-04-16 | 2016-06-05 | 93SS | 25d |  | start no earlier than 2015-09-30 | MO: Capataz incluye leyes sociales [0.5%]; MO: Operador de maquinaria-equipo pesado [43.6%]; MO: Peon incluye leyes sociales [10.9%]; Camión volquete 4x2 210 - 280 HP 8m3 [38.1%]; Cargador sob. llanta 80-95HP 1 5-1 75 Yd3 [5.5%]; Autorización de centro de acopio para disposición final de residuos solidos (Tuberias de concreto p/desague) [1 m3] | 394.44h | 34,838.22 | 01.05.03.03 | 000000000001203 | 15.69 | 68.79 | 1079.32 | 288 |
| 95 | 1.5.3.4 | Corte+rotura, ED y reposición de vereda rígida f'c 175 kg/cm2 de 10 cm espesor | 45d | 2016-04-15 | 2016-05-30 | 15 | 21d | 0d | start no earlier than 2015-09-30 | MO: Ingeniero residente incl. leyes sociales [40.2%]; MO: Técnico incluye leyes sociales [40.2%]; MO: Capataz incluye leyes sociales [671.7%]; MO: Operador de maquinaria-equipo pesado [8865.5%]; MO: Operario incluye leyes sociales [6179.7%]; MO: Oficial incluye leyes sociales [1300.8%]; MO: Peon incluye leyes sociales [19062.4%]; Camión volquete 4x2 210 - 280 HP 8m3 [657%]; Camioneta pick-up 4x2 simple 1000 kg 90 HP [1080.3%]; Camión concretero 6x4 235-300HP 8m3 [1483.9%]; Cargador sob. llanta 80-95HP 1 5-1 75 Yd3 [171.7%]; Compactadora vibrat. de plancha 7 HP [567.6%]; Compresora neumática 76 HP 125 - 175 pcm. [409.1%]; Planta-Dosificadora de concreto PM (planta) [40.2%]; Martillo neumático 21 - 24 kg [787.5%]; Martillo cincel para corte-demolición [787.5%]; Motoniveladora de 85 - 120 HP [172.6%]; Rodillo neumático autoprop. 60-80 HP 3 - 5 ton [172.6%]; Rodillo tandem vibratorio autopropulsado 15-35HP 2 5 - 4 ton [172.6%]; Cortadora de pavimento C35-35HP i/combus [3152.5%]; Vibrador de concreto 4 HP 18PL [1260.5%]; Arena gruesa [106.04 m3]; Material granular S. A1a-A1b AASHTO [236.5 m3]; Piedra partida-grava de 1/2" - 3/4" [146.35 m3]; Agua incluye transporte a pie de obra (Camión cisterna y Motobomba) [700.04 m3]; Agua incluye transporte a pie de obra (Camión cisterna y Motobomba) [42.03 m3]; Madera para encofrado y carpintería [932.76 p2]; Cemento portland I sector público; en bolsa [1739.5 und]; Sika:plastiment HE98 balde de 20 kg [19.14 und]; Regla de madera tipo tornillo especial [18.92 und]; Disco para corte PC 300 de 18" [23.6%] | 169561h | 4,940,811.46 | 01.05.03.04 | 000000000001204 | 1892 | 92.3 | 174631.6 |  |
| 96 | 1.5.3.5 | Excav. zanja (pulso) p/tub. terr-normal DN 15 - 40 de 0,60 m a 1,00 m prof. | 45d | 2016-04-16 | 2016-05-31 | 95SS+1d | 21d | 0d | start no earlier than 2015-09-30 | MO: Capataz incluye leyes sociales [9.3%]; MO: Peon incluye leyes sociales [935.1%] | 3399.91h | 49,399.01 | 01.05.03.05 | 000000000001205 | 975 | 12.63 | 12314.25 | 94.79 |
| 97 | 1.5.3.6 | Refine y nivel de zanja terr-normal para tub. DN 15 - 40 para toda profund. | 45d | 2016-04-16 | 2016-05-31 | 96SS | 30d |  | start no earlier than 2015-09-30 | MO: Capataz incluye leyes sociales [9.8%]; MO: Peon incluye leyes sociales [196.5%] | 742.58h | 11,154.43 | 01.05.03.06 | 000000000001206 | 975 | 1.04 | 1014 | 248.06 |
| 98 | 1.5.3.7 | Relleno comp.zanja(pulso) p/tub t-normal DN 15 - 40 de 0,60 m a 1,00 m prof. | 45d | 2016-04-21 | 2016-06-05 | 96SS+5d | 25d |  | start no earlier than 2015-09-30 | MO: Capataz incluye leyes sociales [21.3%]; MO: Operador de maquinaria-equipo pesado [96.3%]; MO: Peon incluye leyes sociales [950.6%]; Compactadora vibrat. de plancha 7 HP [96.3%]; Arena gruesa [46.12 m3]; Agua incluye transporte a pie de obra (Camión cisterna y Motobomba) [20.48 m3] | 4192h | 65,318.6 | 01.05.03.07 | 000000000001207 | 975 | 11.21 | 10929.75 | 168.78 |
| 99 | 1.5.3.8 | Elimin. desmonte(carg+v) t-normal D=20km p/tub. DN 15 - 40 para toda prof. | 50d | 2016-04-17 | 2016-06-06 | 96SS+1d | 24d |  | start no earlier than 2015-09-30 | MO: Capataz incluye leyes sociales [1.2%]; MO: Operador de maquinaria-equipo pesado [117%]; MO: Peon incluye leyes sociales [58.5%]; Camión volquete 4x2 210 - 280 HP 8m3 [102.4%]; Cargador sob. llanta 80-95HP 1 5-1 75 Yd3 [14.6%]; Autorizacion de centro de acopio para disposicion final de residuos peligrosos [1 m3] | 1174.88h | 95,161.52 | 01.05.03.08 | 000000000001208 | 975 | 2.95 | 2876.25 | 6666.67 |
| 100 | 1.5.3.9 | Tubería de PVC-U SP PN 10 DN 15 incl. elemento unión + 2% desperdicios | 15d | 2016-04-15 | 2016-04-30 | 92SS | 56d | 0d | start no earlier than 2015-09-30 | Flete-transporte de tubería liviana no metálica (PVC HDPE GRP ó similar) [238.88 kg]; Tubo de PVC SP PN 10 DN 15 mm [99450%]; Pegamento para tubo de PVC 1/4 galón [0.97 und] |  | 1,065.04 | 01.05.03.09 | 000000000001209 | 975 | 1.09 | 1062.75 |  |
| 101 | 1.5.3.10 | Instalación de tubería PVC p/agua potab. DN 15 - 20 incluye prueba hidráulica | 45d | 2016-04-18 | 2016-06-02 | 96SS+2d | 21d | 0d | start no earlier than 2015-09-30 | MO: Capataz incluye leyes sociales [42.7%]; MO: Operario incluye leyes sociales [407.1%]; MO: Oficial incluye leyes sociales [407.1%]; MO: Peon incluye leyes sociales [26.8%]; Balde para prueba hidrostático incluye accesorios [325.4%]; Agua incluye transporte a pie de obra (Camión cisterna y Motobomba) [0.97 m3]; Tapón fo. galvanizado UR DN 15 mm (m - h) [1.95 und] | 4352.4h | 57,784.57 | 01.05.03.10 | 000000000001210 | 975 | 1.36 | 1326 | 1200 |
| 102 | 1.5.3.11 | Prueba hidráulica de tubería agua para potable (incl. desinfección) DN 15 - 20 | 50d | 2016-04-20 | 2016-06-09 | 101SS+2d | 21d |  | start no earlier than 2015-09-30 | MO: Capataz incluye leyes sociales [8.2%]; MO: Operario incluye leyes sociales [81.4%]; MO: Oficial incluye leyes sociales [81.4%]; Balde para prueba hidrostático incluye accesorios [81.4%]; Hipoclorito de calcio al 70% [0.97 kg]; Agua incluye transporte a pie de obra (Camión cisterna y Motobomba) [0.97 m3]; Tapón fo. galvanizado UR DN 15 mm (m - h) [1.95 und] | 1009.12h | 12,541.03 | 01.05.03.11 | 000000000001211 | 975 | 1.08 | 1053 | 300 |
| 103 | 1.5.3.12 | Tubería de PVC-SAP DN 75mm + 2% desperdicios | 15d | 2016-04-15 | 2016-04-30 | 100SS | 61d |  | start no earlier than 2015-09-30 | Flete-transporte de tubería liviana no metálica (PVC HDPE GRP ó similar) [686.4 kg]; Tubo de PVC SP PN 10 D 11/2" [99450%]; Pegamento para tubo de PVC 1/4 galón [1.95 und] |  | 1,074.31 | 01.05.03.12 | 000000000001212 | 975 | 1.1 | 1072.5 |  |
| 104 | 1.5.3.13 | Instalación de tubería PVC-SAP para forro de conexión de agua potable | 45d | 2016-04-18 | 2016-06-02 | 101SS | 23d | 0d | start no earlier than 2015-09-30 | MO: Capataz incluye leyes sociales [6.7%]; MO: Operario incluye leyes sociales [50.6%]; MO: Oficial incluye leyes sociales [50.6%]; MO: Peon incluye leyes sociales [84.7%] | 693.23h | 11,484.87 | 01.05.03.13 | 000000000001213 | 975 | 0.53 | 516.75 | 960 |
| 105 | 1.5.3.14 | Instalación elementos de control para conexión agua DN 15 - 25 | 45d | 2016-04-18 | 2016-06-02 | 104SS | 23d | 0d | start no earlier than 2015-09-30 | MO: Capataz incluye leyes sociales [9.2%]; MO: Operario incluye leyes sociales [92.3%] | 365.63h | 7,330.45 | 01.05.03.14 | 000000000001214 | 325 | 5.63 | 1829.75 | 32 |
| 106 | 1.5.3.15 | Suministro de caja, marco y tapa termoplastica con seguro (CTPS-E-004:2005 ó su actualización), para medidor DN 15 - 20 mm | 15d | 2016-04-15 | 2016-04-30 | 100SS | 61d |  | start no earlier than 2015-09-30 | Marco y Tapa termoplastico p/ medidor de agua de 1/2" y 3/4" (CTPS-E-004:2005 ó su actualización) [325 und]; Caja incluye solado termoplastico p/ medidor de agua de 15 (1/2") y 20 (3/4") (CTPS-E-004:2005 ó su actualización) [325 und] |  | 20,800 | 01.05.03.15 | 000000000001215 | 325 | 64 | 20800 |  |
| 107 | 1.5.3.16 | Instalación de caja y tapa para medidor DN 15 a 20 en terreno normal | 50d | 2016-04-18 | 2016-06-07 | 105SS | 23d |  | start no earlier than 2015-09-30 | MO: Capataz incluye leyes sociales [9.7%]; MO: Operador de maquinaria-equipo pesado [24.2%]; MO: Operario incluye leyes sociales [96.7%]; MO: Oficial incluye leyes sociales [24.2%]; MO: Peon incluye leyes sociales [362.7%]; Camión volquete 4x2 140 - 210 HP 6m3 [24.2%]; Arena gruesa [2.92 m3]; Piedra partida-grava de 1/2" - 3/4" [5.2 m3]; Cemento portland I sector público; en bolsa [38.67 und] | 2166.47h | 48,627.14 | 01.05.03.16 | 000000000001216 | 325 | 44.76 | 14547 | 24 |
| 108 | 1.6 | **SUMINISTRO E INSTAL. DE TUBERIAS** | 62d | 2016-04-15 | 2016-06-16 |  | 14d |  |  |  | 12877.1h | 569,799.42 | 01.06 | 000000000001217 |  |  |  |  |
| 109 | 1.6.1 | Suministro de tuberia HDPE SN-2 NTP-ISO 8772:2009 DN 200 mm | 20d | 2016-04-15 | 2016-05-05 | 100SS | 56d | 0d | start no earlier than 2015-09-30 | Flete-transporte de tubería liviana no metálica (PVC HDPE GRP ó similar) [21483.4 kg]; TUBERIA HDPE NTP ISO 8772:2009 SN-2 DN = 200 mm [324714%] |  | 270,241.81 | 01.06.01 | 000000000001218 | 3152.56 | 85.72 | 270237.44 |  |
| 110 | 1.6.2 | Suministro de tuberia HDPE SN-2 NTP-ISO 8772:2009 DN 250 mm | 20d | 2016-04-15 | 2016-05-05 | 109SS | 56d | 0d | start no earlier than 2015-09-30 | Flete-transporte de tubería liviana no metálica (PVC HDPE GRP ó similar) [2556.29 kg]; TUBERIA HDPE NTP ISO 8772:2009 SN-2 DN = 250 mm [38637.4%] |  | 50,052.63 | 01.06.02 | 000000000001316 | 375.12 | 133.43 | 50052.26 |  |
| 111 | 1.6.3 | Tubería PVC-U UF NTP ISO 4435 SN 2 DN 300 incl. anillo + 2% desperdicios | 20d | 2016-04-15 | 2016-05-05 | 110SS | 56d |  | start no earlier than 2015-09-30 | Flete-transporte de tubería liviana no metálica (PVC HDPE GRP ó similar) [1489.96 kg]; TUBERIA HDPE NTP ISO 8772:2009 SN-2 DN = 315 mm [14157.4%] |  | 29,099.15 | 01.06.03 | 000000000001219 | 137.45 | 211.7 | 29098.17 |  |
| 112 | 1.6.4 | Instalación tuberia HDPE unión por termofusión DN 200 mm incluye prueba hidráulica a zanja abierta | 61d | 2016-04-16 | 2016-06-16 | 41SS+1d | 13d | 0d | start no earlier than 2015-09-30 | MO: Capataz incluye leyes sociales [37.7%]; MO: Operario incluye leyes sociales [344%]; MO: Oficial incluye leyes sociales [344%]; MO: Peon incluye leyes sociales [406.5%]; Agua incluye transporte a pie de obra (Camión cisterna y Motobomba) [217.53 m3]; Tapón de acero DN 200 mm [6.31 und] | 5524.68h | 96,150.31 | 01.06.04 | 000000000001220 | 3152.56 | 4.49 | 14154.99 | 480 |
| 113 | 1.6.5 | Instalación tuberia HDPE unión por termofusión DN 250 mm incluye prueba hidráulica a zanja abierta | 61d | 2016-04-16 | 2016-06-16 | 112SS | 13d | 0d | start no earlier than 2015-09-30 | MO: Capataz incluye leyes sociales [36.1%]; MO: Operario incluye leyes sociales [325.9%]; MO: Oficial incluye leyes sociales [325.9%]; MO: Peon incluye leyes sociales [404.2%]; Agua incluye transporte a pie de obra (Camión cisterna y Motobomba) [34.14 m3]; Tapón de acero DN 250 mm [0.75 und]; Servicio de termofusión para unir tubería HDPE DN 250 pared lisa (Inl. equipo termofusión y G.E. costo prorrateo por m [1 und] | 5329.28h | 89,977.71 | 01.06.05 | 000000000001317 | 375.12 | 16.28 | 6106.95 | 411 |
| 114 | 1.6.6 | Instalación de tubería de PVC p/desagüe DN 300 incluye prueba hidráulica a zanja abierta | 61d | 2016-04-16 | 2016-06-16 | 113SS | 13d | 0d | start no earlier than 2015-09-30 | MO: Capataz incluye leyes sociales [13.7%]; MO: Operario incluye leyes sociales [124%]; MO: Oficial incluye leyes sociales [124%]; MO: Peon incluye leyes sociales [152.7%]; Agua incluye transporte a pie de obra (Camión cisterna y Motobomba) [16.36 m3]; Tapón de acero DN 300 mm [0.27 und]; Servicio de termofusión para unir tubería HDPE DN 315 pared lisa (Inl. equipo termofusión y G.E. costo prorrateo por m [1 und] | 2023.17h | 34,277.8 | 01.06.06 | 000000000001221 | 137.45 | 17.72 | 2435.61 | 360 |

| ID | WBS | Task | Duration | Start | Finish | Predecessors | Total slack | Free slack | Constraint | Resources | Work | Cost | Text1 | Text8 | Text2 | Text3 | Text4 | Text6 |
| --- | --- | --- | --- | --- | --- | --- | --- | --- | --- | --- | --- | --- | --- | --- | --- | --- | --- | --- |
| 115 | 1.7 | **PRUEBAS HIDRAULICAS Y DE RESISTENCIA** | 61d | 2016-04-17 | 2016-06-17 |  | 13d |  |  |  | 6765.97h | 135,110.91 | 01.07 | 000000000001222 |  |  |  |  |
| 116 | 1.7.1 | Prueba hidráulica de tubería p/desague DN 200 | 61d | 2016-04-17 | 2016-06-17 | 112SS+1d | 13d |  | start no earlier than 2015-09-30 | MO: Capataz incluye leyes sociales [9.6%]; MO: Operario incluye leyes sociales [97.2%]; MO: Oficial incluye leyes sociales [97.2%]; MO: Peon incluye leyes sociales [97.2%]; Agua incluye transporte a pie de obra (Camión cisterna y Motobomba) [217.53 m3]; Tapón de acero DN 200 mm [6.31 und] | 1470.07h | 28,123.65 | 01.07.01 | 000000000001223 | 3152.56 | 3.41 | 10750.23 | 180 |
| 117 | 1.7.2 | Prueba hidráulica de tubería p/desague DN 250 | 61d | 2016-04-17 | 2016-06-17 | 113SS+1d | 13d |  | start no earlier than 2015-09-30 | MO: Capataz incluye leyes sociales [7.8%]; MO: Operario incluye leyes sociales [78.2%]; MO: Oficial incluye leyes sociales [78.2%]; MO: Peon incluye leyes sociales [78.2%]; Agua incluye transporte a pie de obra (Camión cisterna y Motobomba) [34.14 m3]; Tapón de acero DN 250 mm [0.75 und] | 1182.25h | 20,511.77 | 01.07.02 | 000000000001318 | 375.12 | 4.02 | 1507.98 | 160 |
| 118 | 1.7.3 | Prueba hidráulica de tubería p/desague DN 300 | 61d | 2016-04-17 | 2016-06-17 | 114SS+1d | 13d |  | start no earlier than 2015-09-30 | MO: Capataz incluye leyes sociales [8.6%]; MO: Operario incluye leyes sociales [85.9%]; MO: Oficial incluye leyes sociales [85.9%]; MO: Peon incluye leyes sociales [85.9%]; Agua incluye transporte a pie de obra (Camión cisterna y Motobomba) [16.36 m3]; Tapón de acero DN 300 mm [0.27 und] | 1299.59h | 22,246.9 | 01.07.03 | 000000000001224 | 137.45 | 4.52 | 621.27 | 160 |
| 119 | 1.7.4 | Prueba de calidad del concreto (prueba a la compresión) | 55d | 2016-04-17 | 2016-06-11 | 127SS | 19d |  | start no earlier than 2015-09-30 | MO: Operador de maquinaria-equipo pesado [95.8%]; Camioneta pick-up 4x2 simple 1000 kg 90 HP [95.8%]; Prueba: rotura de probeta [287.5%] | 2108.25h | 38,263.69 | 01.07.04 | 000000000001225 | 138 | 30.25 | 4174.5 | 24 |
| 120 | 1.7.5 | Prueba de compactacion de suelos (proctor modificado y de control de compactacion - densidad de campo) | 58d | 2016-04-20 | 2016-06-17 | 82SS+2d | 13d |  | start no earlier than 2015-09-30 | MO: Operador de maquinaria-equipo pesado [76.1%]; Camioneta pick-up 4x2 simple 1000 kg 90 HP [76.1%]; Prueba: Control de compactación (densidad de campo) [73 und]; Prueba: proctor modificado de campo [3.65 und] | 705.81h | 25,964.91 | 01.07.05 | 000000000001226 | 73 | 72.12 | 5264.76 | 48 |
| 121 | 1.8 | **BUZONES** | 60d | 2016-04-17 | 2016-06-16 |  | 14d |  |  |  | 399574h | 6,455,997.36 | 01.08 | 000000000001227 |  |  |  |  |
| 122 | 1.8.1 | Reconstrucción de buzón I t-normal, a pulso, de 1,01 a 1,25 m profundidad (encof. exterior e interior) | 50d | 2016-04-17 | 2016-06-06 | 26SS+1d | 24d | 0d | start no earlier than 2015-09-30 | MO: Capataz incluye leyes sociales [242.5%]; MO: Operador de maquinaria-equipo pesado [356.8%]; MO: Operario incluye leyes sociales [2166.3%]; MO: Oficial incluye leyes sociales [1155.2%]; MO: Peon incluye leyes sociales [5996.3%]; Cizalla para corte de fierro [129.2%]; Tecle t/trípode inc. cadena para 5 tonel. [29.2%]; Andamio de metal y/o de madera (alquiler) [76.1%]; Camión volquete 4x2 210 - 280 HP 8m3 [127.8%]; Mezcladora concreto t/tambor23HP 11-12p3 [114.8%]; Compactadora vibrat. de plancha 7 HP [114.3%]; Vibrador de concreto 4 HP 18PL [98%]; Vibrador de concreto 4 HP 18PL (1 5") [110.2%]; Alambre negro N° 8 [6.92 kg]; Alambre negro N° 16 [13.3 kg]; Clavo c/cabeza para madera (promedio) [11.09 kg]; Fo. construcción : (costo promedio) [279.3 kg]; Encofrado metálico p/construcción cajas-similar [1463%]; Arena fina [0.33 m3]; Arena gruesa [14.34 m3]; Piedra partida-grava de 1/2" - 3/4" [24.47 m3]; Agua incluye transporte a pie de obra (Camión cisterna y Motobomba) [2.47 m3]; Agua incluye transporte a pie de obra (Camión cisterna y Motobomba) [6.03 m3]; Autorización de centro de acopio para disposición final de residuos solidos (material desmonte no peligroso) [1 m3]; Madera para encofrado y carpintería [219.9 p2]; Cemento portland I sector público; en bolsa [254.45 und]; Sika:plastiment HE98 balde de 20 kg [3.4 und]; Tapa de concreto armado perfil FF de 0 60 m [14 und]; Marco de fierro fundido de diámetro 0 60 m [14 und] | 48718.7h | 788,026.99 | 01.08.01 | 000000000001319 | 14 | 1974.42 | 27641.88 |  |
| 123 | 1.8.2 | Reconstrucción de buzón I t-normal, a pulso, de 1,26 a 1,50 m profundidad (encof. exterior e interior) | 50d | 2016-04-17 | 2016-06-06 | 27SS+1d | 24d | 0d | start no earlier than 2015-09-30 | MO: Capataz incluye leyes sociales [243%]; MO: Operador de maquinaria-equipo pesado [359.1%]; MO: Operario incluye leyes sociales [2139.6%]; MO: Oficial incluye leyes sociales [1093.5%]; MO: Peon incluye leyes sociales [6311.9%]; Cizalla para corte de fierro [120%]; Tecle t/trípode inc. cadena para 5 tonel. [27.1%]; Andamio de metal y/o de madera (alquiler) [70.7%]; Camión volquete 4x2 210 - 280 HP 8m3 [130.8%]; Mezcladora concreto t/tambor23HP 11-12p3 [113.4%]; Compactadora vibrat. de plancha 7 HP [114.9%]; Vibrador de concreto 4 HP 18PL [105.1%]; Vibrador de concreto 4 HP 18PL (1 5") [102.4%]; Alambre negro N° 8 [6.42 kg]; Alambre negro N° 16 [12.35 kg]; Clavo c/cabeza para madera (promedio) [10.3 kg]; Fo. construcción : (costo promedio) [259.35 kg]; Encofrado metálico p/construcción cajas-similar [1573%]; Arena fina [0.31 m3]; Arena gruesa [14.14 m3]; Piedra partida-grava de 1/2" - 3/4" [24.16 m3]; Agua incluye transporte a pie de obra (Camión cisterna y Motobomba) [2.47 m3]; Agua incluye transporte a pie de obra (Camión cisterna y Motobomba) [5.95 m3]; Autorización de centro de acopio para disposición final de residuos solidos (material desmonte no peligroso) [1 m3]; Madera para encofrado y carpintería [204.19 p2]; Cemento portland I sector público; en bolsa [251.02 und]; Sika:plastiment HE98 balde de 20 kg [3.38 und]; Tapa de concreto armado perfil FF de 0 60 m [13 und]; Marco de fierro fundido de diámetro 0 60 m [13 und] | 50017.4h | 802,991.42 | 01.08.02 | 000000000001228 | 13 | 2119.95 | 27559.35 |  |
| 124 | 1.8.3 | Reconstrucción de buzón I t-normal, a pulso, de 1,51 a 1,75 m profundidad (encof. exterior e interior) | 50d | 2016-04-17 | 2016-06-06 | 28SS+1d | 24d | 0d | start no earlier than 2015-09-30 | MO: Capataz incluye leyes sociales [311.3%]; MO: Operador de maquinaria-equipo pesado [467.4%]; MO: Operario incluye leyes sociales [2715.8%]; MO: Oficial incluye leyes sociales [1302.4%]; MO: Peon incluye leyes sociales [8378.8%]; Cizalla para corte de fierro [138.4%]; Tecle t/trípode inc. cadena para 5 tonel. [31.3%]; Andamio de metal y/o de madera (alquiler) [81.6%]; Camión volquete 4x2 210 - 280 HP 8m3 [174.4%]; Mezcladora concreto t/tambor23HP 11-12p3 [144%]; Compactadora vibrat. de plancha 7 HP [149.1%]; Vibrador de concreto 4 HP 18PL [148.8%]; Vibrador de concreto 4 HP 18PL (1 5") [118.1%]; Alambre negro N° 8 [7.41 kg]; Alambre negro N° 16 [14.25 kg]; Clavo c/cabeza para madera (promedio) [11.88 kg]; Fo. construcción : (costo promedio) [299.25 kg]; Encofrado metálico p/construcción cajas-similar [2227.5%]; Arena fina [0.36 m3]; Arena gruesa [17.93 m3]; Piedra partida-grava de 1/2" - 3/4" [30.68 m3]; Agua incluye transporte a pie de obra (Camión cisterna y Motobomba) [3.17 m3]; Agua incluye transporte a pie de obra (Camión cisterna y Motobomba) [7.56 m3]; Autorización de centro de acopio para disposición final de residuos solidos (material desmonte no peligroso) [1 m3]; Madera para encofrado y carpintería [235.6 p2]; Cemento portland I sector público; en bolsa [318.41 und]; Sika:plastiment HE98 balde de 20 kg [4.33 und]; Tapa de concreto armado perfil FF de 0 60 m [15 und]; Marco de fierro fundido de diámetro 0 60 m [15 und] | 65555.1h | 1,044,000.02 | 01.08.03 | 000000000001229 | 15 | 2336.57 | 35048.55 |  |
| 125 | 1.8.4 | Reconstrucción de buzón I t-normal, a pulso, de 1,76 a 2,00 m profundidad (encof. exterior e interior) | 50d | 2016-04-17 | 2016-06-06 | 29SS+1d | 24d | 0d | start no earlier than 2015-09-30 | MO: Capataz incluye leyes sociales [392.2%]; MO: Operador de maquinaria-equipo pesado [590.4%]; MO: Operario incluye leyes sociales [3356.7%]; MO: Oficial incluye leyes sociales [1522.2%]; MO: Peon incluye leyes sociales [11191.2%]; Cizalla para corte de fierro [156.9%]; Tecle t/trípode inc. cadena para 5 tonel. [35.4%]; Andamio de metal y/o de madera (alquiler) [92.5%]; Camión volquete 4x2 210 - 280 HP 8m3 [224.2%]; Mezcladora concreto t/tambor23HP 11-12p3 [178.2%]; Compactadora vibrat. de plancha 7 HP [188.1%]; Vibrador de concreto 4 HP 18PL [199.8%]; Vibrador de concreto 4 HP 18PL (1 5") [133.9%]; Alambre negro N° 8 [8.4 kg]; Alambre negro N° 16 [16.15 kg]; Clavo c/cabeza para madera (promedio) [13.46 kg]; Fo. construcción : (costo promedio) [339.15 kg]; Encofrado metálico p/construcción cajas-similar [2989.9%]; Arena fina [0.4 m3]; Arena gruesa [22.16 m3]; Piedra partida-grava de 1/2" - 3/4" [37.95 m3]; Agua incluye transporte a pie de obra (Camión cisterna y Motobomba) [3.97 m3]; Agua incluye transporte a pie de obra (Camión cisterna y Motobomba) [9.35 m3]; Autorización de centro de acopio para disposición final de residuos solidos (material desmonte no peligroso) [1 m3]; Madera para encofrado y carpintería [267.02 p2]; Cemento portland I sector público; en bolsa [393.48 und]; Sika:plastiment HE98 balde de 20 kg [5.39 und]; Tapa de concreto armado perfil FF de 0 60 m [17 und]; Marco de fierro fundido de diámetro 0 60 m [17 und] | 85005.8h | 1,342,888.9 | 01.08.04 | 000000000001230 | 17 | 2585.06 | 43946.02 |  |
| 126 | 1.8.5 | Reconstrucción de buzón I t-normal, a pulso, de 2,01 a 2,50 m profundidad (encof. exterior e interior) | 50d | 2016-04-17 | 2016-06-06 | 30SS+1d | 24d | 0d | start no earlier than 2015-09-30 | MO: Capataz incluye leyes sociales [364.1%]; MO: Operador de maquinaria-equipo pesado [556.7%]; MO: Operario incluye leyes sociales [3087.4%]; MO: Oficial incluye leyes sociales [1307.1%]; MO: Peon incluye leyes sociales [10720.2%]; Cizalla para corte de fierro [129.2%]; Tecle t/trípode inc. cadena para 5 tonel. [29.2%]; Andamio de metal y/o de madera (alquiler) [76.1%]; Camión volquete 4x2 210 - 280 HP 8m3 [215.7%]; Mezcladora concreto t/tambor23HP 11-12p3 [164.1%]; Compactadora vibrat. de plancha 7 HP [176.9%]; Vibrador de concreto 4 HP 18PL [200.7%]; Vibrador de concreto 4 HP 18PL (1 5") [110.2%]; Alambre negro N° 8 [6.92 kg]; Alambre negro N° 16 [13.3 kg]; Clavo c/cabeza para madera (promedio) [11.09 kg]; Fo. construcción : (costo promedio) [279.3 kg]; Encofrado metálico p/construcción cajas-similar [3001.2%]; Arena fina [0.33 m3]; Arena gruesa [20.37 m3]; Piedra partida-grava de 1/2" - 3/4" [34.94 m3]; Agua incluye transporte a pie de obra (Camión cisterna y Motobomba) [3.7 m3]; Agua incluye transporte a pie de obra (Camión cisterna y Motobomba) [8.61 m3]; Autorización de centro de acopio para disposición final de residuos solidos (material desmonte no peligroso) [1 m3]; Madera para encofrado y carpintería [219.9 p2]; Cemento portland I sector público; en bolsa [361.88 und]; Sika:plastiment HE98 balde de 20 kg [5 und]; Tapa de concreto armado perfil FF de 0 60 m [14 und]; Marco de fierro fundido de diámetro 0 60 m [14 und] | 80555.6h | 1,264,147.52 | 01.08.05 | 000000000001231 | 14 | 2895.84 | 40541.76 |  |
| 127 | 1.8.6 | Reconstrucción de buzón I t-normal, a pulso, de 2,51 a 3,00 m profundidad (encof. exterior e interior) | 50d | 2016-04-17 | 2016-06-06 | 31SS+1d | 14d | 0d | start no earlier than 2015-09-30 | MO: Capataz incluye leyes sociales [123%]; MO: Operador de maquinaria-equipo pesado [187.5%]; MO: Operario incluye leyes sociales [1013.8%]; MO: Oficial incluye leyes sociales [395.2%]; MO: Peon incluye leyes sociales [3891.7%]; Cizalla para corte de fierro [36.9%]; Tecle t/trípode inc. cadena para 5 tonel. [8.3%]; Andamio de metal y/o de madera (alquiler) [21.8%]; Camión volquete 4x2 210 - 280 HP 8m3 [74.1%]; Mezcladora concreto t/tambor23HP 11-12p3 [53.9%]; Compactadora vibrat. de plancha 7 HP [59.5%]; Vibrador de concreto 4 HP 18PL [72%]; Vibrador de concreto 4 HP 18PL (1 5") [31.5%]; Alambre negro N° 8 [1.98 kg]; Alambre negro N° 16 [3.8 kg]; Clavo c/cabeza para madera (promedio) [3.17 kg]; Fo. construcción : (costo promedio) [79.8 kg]; Encofrado metálico p/construcción cajas-similar [1077.5%]; Arena fina [0.1 m3]; Arena gruesa [6.68 m3]; Piedra partida-grava de 1/2" - 3/4" [11.48 m3]; Agua incluye transporte a pie de obra (Camión cisterna y Motobomba) [1.23 m3]; Agua incluye transporte a pie de obra (Camión cisterna y Motobomba) [2.83 m3]; Autorización de centro de acopio para disposición final de residuos solidos (material desmonte no peligroso) [1 m3]; Madera para encofrado y carpintería [62.83 p2]; Cemento portland I sector público; en bolsa [118.74 und]; Sika:plastiment HE98 balde de 20 kg [1.66 und]; Tapa de concreto armado perfil FF de 0 60 m [4 und]; Marco de fierro fundido de diámetro 0 60 m [4 und] | 28186.7h | 438,209.34 | 01.08.06 | 000000000001232 |  | 3402.3 | 13609.2 |  |
| 128 | 1.8.7 | Buzón I t. normal a máq. 1,01 a 1,25 m profundidad (encof. exter e inter) C-PV | 50d | 2016-04-17 | 2016-06-06 | 122SS | 24d |  | start no earlier than 2015-09-30 | MO: Capataz incluye leyes sociales [75.5%]; MO: Operador de maquinaria-equipo pesado [119.7%]; MO: Operario incluye leyes sociales [773.7%]; MO: Oficial incluye leyes sociales [431.7%]; MO: Peon incluye leyes sociales [1428.5%]; Cizalla para corte de fierro [46.1%]; Tecle t/trípode inc. cadena para 5 tonel. [10.4%]; Andamio de metal y/o de madera (alquiler) [27.2%]; Camión volquete 4x2 210 - 280 HP 8m3 [35.5%]; Mezcladora concreto t/tambor23HP 11-12p3 [41%]; Cargador sob. llanta 80-95HP 1 5-1 75 Yd3 [9.4%]; Cargador retroexcava dor 0 5-0 75Yd3 62HP [19.1%]; Compactadora vibrat. de plancha 7 HP [10.3%]; Rodillo liso vibrat. 0 8-1 1 ton manual ó de control remoto [4.4%]; Vibrador de concreto 4 HP 18PL (1 5") [74.4%]; Alambre negro N° 8 [2.47 kg]; Alambre negro N° 16 [4.75 kg]; Clavo c/cabeza para madera (promedio) [3.96 kg]; Fo. construcción : (costo promedio) [99.75 kg]; Encofrado metálico p/construcción cajas-similar [522.5%]; Arena fina [0.12 m3]; Arena gruesa [5.12 m3]; Piedra partida-grava de 1/2" - 3/4" [8.74 m3]; Agua incluye transporte a pie de obra (Camión cisterna y Motobomba) [0.88 m3]; Agua incluye transporte a pie de obra (Camión cisterna y Motobomba) [2.15 m3]; Autorización de centro de acopio para disposición final de residuos solidos (Tuberias de concreto p/desague) [1 m3]; Madera para encofrado y carpintería [78.53 p2]; Cemento portland I sector público; en bolsa [2.97 und]; Cemento portland V sector público; en bolsa [87.9 und]; Sika:plastiment HE98 balde de 20 kg [1.22 und]; Tapa de concreto armado perfil FF de 0 60 m [5 und]; Marco de fierro fundido de diámetro 0 60 m [5 und] | 14517.9h | 244,457.95 | 01.08.07 | 000000000001236 |  | 1928.15 | 9640.75 |  |
| 129 | 1.8.8 | Buzón I t. normal a máq. 1,26 a 1,50 m profundidad (encof. exter e inter) C-PV | 50d | 2016-04-17 | 2016-06-06 | 123SS | 24d |  | start no earlier than 2015-09-30 | MO: Capataz incluye leyes sociales [48.3%]; MO: Operador de maquinaria-equipo pesado [77.8%]; MO: Operario incluye leyes sociales [493.8%]; MO: Oficial incluye leyes sociales [265%]; MO: Peon incluye leyes sociales [943.1%]; Cizalla para corte de fierro [27.7%]; Tecle t/trípode inc. cadena para 5 tonel. [6.3%]; Andamio de metal y/o de madera (alquiler) [16.3%]; Camión volquete 4x2 210 - 280 HP 8m3 [23.5%]; Mezcladora concreto t/tambor23HP 11-12p3 [26.2%]; Cargador sob. llanta 80-95HP 1 5-1 75 Yd3 [6.2%]; Cargador retroexcava dor 0 5-0 75Yd3 62HP [12.6%]; Compactadora vibrat. de plancha 7 HP [6.4%]; Rodillo liso vibrat. 0 8-1 1 ton manual ó de control remoto [2.9%]; Vibrador de concreto 4 HP 18PL (1 5") [47.9%]; Alambre negro N° 8 [1.48 kg]; Alambre negro N° 16 [2.85 kg]; Clavo c/cabeza para madera (promedio) [2.38 kg]; Fo. construcción : (costo promedio) [59.85 kg]; Encofrado metálico p/construcción cajas-similar [363%]; Arena fina [0.07 m3]; Arena gruesa [3.26 m3]; Piedra partida-grava de 1/2" - 3/4" [5.58 m3]; Agua incluye transporte a pie de obra (Camión cisterna y Motobomba) [0.57 m3]; Agua incluye transporte a pie de obra (Camión cisterna y Motobomba) [1.37 m3]; Autorización de centro de acopio para disposición final de residuos solidos (Tuberias de concreto p/desague) [1 m3]; Madera para encofrado y carpintería [47.12 p2]; Cemento portland I sector público; en bolsa [1.78 und]; Cemento portland V sector público; en bolsa [56.14 und]; Sika:plastiment HE98 balde de 20 kg [0.78 und]; Tapa de concreto armado perfil FF de 0 60 m [3 und]; Marco de fierro fundido de diámetro 0 60 m [3 und] | 9467.49h | 158,369.28 | 01.08.08 | 000000000001237 |  | 2048.73 | 6146.19 |  |
| 130 | 1.8.9 | Buzón I t. normal a máq. 1,51 a 1,75 m profundidad (encof. exter e inter) C-PV | 50d | 2016-04-17 | 2016-06-06 | 124SS | 24d |  | start no earlier than 2015-09-30 | MO: Capataz incluye leyes sociales [17.8%]; MO: Operador de maquinaria-equipo pesado [29.3%]; MO: Operario incluye leyes sociales [181.1%]; MO: Oficial incluye leyes sociales [91.7%]; MO: Peon incluye leyes sociales [362.4%]; Cizalla para corte de fierro [9.2%]; Tecle t/trípode inc. cadena para 5 tonel. [2.1%]; Andamio de metal y/o de madera (alquiler) [5.4%]; Camión volquete 4x2 210 - 280 HP 8m3 [9%]; Mezcladora concreto t/tambor23HP 11-12p3 [9.6%]; Cargador sob. llanta 80-95HP 1 5-1 75 Yd3 [2.4%]; Cargador retroexcava dor 0 5-0 75Yd3 62HP [4.8%]; Compactadora vibrat. de plancha 7 HP [2.3%]; Rodillo liso vibrat. 0 8-1 1 ton manual ó de control remoto [1.1%]; Vibrador de concreto 4 HP 18PL (1 5") [17.8%]; Alambre negro N° 8 [0.49 kg]; Alambre negro N° 16 [0.95 kg]; Clavo c/cabeza para madera (promedio) [0.79 kg]; Fo. construcción : (costo promedio) [19.95 kg]; Encofrado metálico p/construcción cajas-similar [148.5%]; Arena fina [0.02 m3]; Arena gruesa [1.2 m3]; Piedra partida-grava de 1/2" - 3/4" [2.05 m3]; Agua incluye transporte a pie de obra (Camión cisterna y Motobomba) [0.21 m3]; Agua incluye transporte a pie de obra (Camión cisterna y Motobomba) [0.5 m3]; Autorización de centro de acopio para disposición final de residuos solidos (Tuberias de concreto p/desague) [1 m3]; Madera para encofrado y carpintería [15.71 p2]; Cemento portland I sector público; en bolsa [0.59 und]; Cemento portland V sector público; en bolsa [20.63 und]; Sika:plastiment HE98 balde de 20 kg [0.29 und]; Tapa de concreto armado perfil FF de 0 60 m [1 und]; Marco de fierro fundido de diámetro 0 60 m [1 und] | 3577.87h | 59,319.61 | 01.08.09 | 000000000001238 |  | 2251.09 | 2251.09 |  |
| 131 | 1.8.10 | Buzón I t. normal a máq. 1,76 a 2,00 m profundidad (encof. exter e inter) C-PV | 50d | 2016-04-17 | 2016-06-06 | 125SS | 24d |  | start no earlier than 2015-09-30 | MO: Capataz incluye leyes sociales [38.9%]; MO: Operador de maquinaria-equipo pesado [65.2%]; MO: Operario incluye leyes sociales [394.9%]; MO: Oficial incluye leyes sociales [190.1%]; MO: Peon incluye leyes sociales [820.6%]; Cizalla para corte de fierro [18.5%]; Tecle t/trípode inc. cadena para 5 tonel. [4.2%]; Andamio de metal y/o de madera (alquiler) [10.9%]; Camión volquete 4x2 210 - 280 HP 8m3 [20.5%]; Mezcladora concreto t/tambor23HP 11-12p3 [21%]; Cargador sob. llanta 80-95HP 1 5-1 75 Yd3 [5.4%]; Cargador retroexcava dor 0 5-0 75Yd3 62HP [11%]; Compactadora vibrat. de plancha 7 HP [4.9%]; Rodillo liso vibrat. 0 8-1 1 ton manual ó de control remoto [2.5%]; Vibrador de concreto 4 HP 18PL (1 5") [39.3%]; Alambre negro N° 8 [0.99 kg]; Alambre negro N° 16 [1.9 kg]; Clavo c/cabeza para madera (promedio) [1.58 kg]; Fo. construcción : (costo promedio) [39.9 kg]; Encofrado metálico p/construcción cajas-similar [351.8%]; Arena fina [0.05 m3]; Arena gruesa [2.61 m3]; Piedra partida-grava de 1/2" - 3/4" [4.46 m3]; Agua incluye transporte a pie de obra (Camión cisterna y Motobomba) [0.47 m3]; Agua incluye transporte a pie de obra (Camión cisterna y Motobomba) [1.1 m3]; Autorización de centro de acopio para disposición final de residuos solidos (Tuberias de concreto p/desague) [1 m3]; Madera para encofrado y carpintería [31.41 p2]; Cemento portland I sector público; en bolsa [1.19 und]; Cemento portland V sector público; en bolsa [45.1 und]; Sika:plastiment HE98 balde de 20 kg [0.63 und]; Tapa de concreto armado perfil FF de 0 60 m [2 und]; Marco de fierro fundido de diámetro 0 60 m [2 und] | 7997.43h | 131,631.87 | 01.08.10 | 000000000001239 |  | 2453.22 | 4906.44 |  |
| 132 | 1.8.11 | Buzón I t. normal a máq. 2,01 a 2,50 m profundidad (encof. exter e inter) C-PV | 50d | 2016-04-17 | 2016-06-06 | 126SS | 24d |  | start no earlier than 2015-09-30 | MO: Capataz incluye leyes sociales [21.8%]; MO: Operador de maquinaria-equipo pesado [37.3%]; MO: Operario incluye leyes sociales [220.5%]; MO: Oficial incluye leyes sociales; MO: Peon incluye leyes sociales [477.8%]; Cizalla para corte de fierro [9.2%]; Tecle t/trípode inc. cadena para 5 tonel. [2.1%]; Andamio de metal y/o de madera (alquiler) [5.4%]; Camión volquete 4x2 210 - 280 HP 8m3 [12%]; Mezcladora concreto t/tambor23HP 11-12p3 [11.7%]; Cargador sob. llanta 80-95HP 1 5-1 75 Yd3 [3.1%]; Cargador retroexcava dor 0 5-0 75Yd3 62HP [6.4%]; Compactadora vibrat. de plancha 7 HP [2.6%]; Rodillo liso vibrat. 0 8-1 1 ton manual ó de control remoto [1.4%]; Vibrador de concreto 4 HP 18PL (1 5") [22.2%]; Alambre negro N° 8 [0.49 kg]; Alambre negro N° 16 [0.95 kg]; Clavo c/cabeza para madera (promedio) [0.79 kg]; Fo. construcción : (costo promedio) [19.95 kg]; Encofrado metálico p/construcción cajas-similar [214.4%]; Arena fina [0.02 m3]; Arena gruesa [1.46 m3]; Piedra partida-grava de 1/2" - 3/4" [2.5 m3]; Agua incluye transporte a pie de obra (Camión cisterna y Motobomba) [0.26 m3]; Agua incluye transporte a pie de obra (Camión cisterna y Motobomba) [0.62 m3]; Autorización de centro de acopio para disposición final de residuos solidos (Tuberias de concreto p/desague) [1 m3]; Madera para encofrado y carpintería [15.71 p2]; Cemento portland I sector público; en bolsa [0.59 und]; Cemento portland V sector público; en bolsa [25.25 und]; Sika:plastiment HE98 balde de 20 kg [0.36 und]; Tapa de concreto armado perfil FF de 0 60 m [1 und]; Marco de fierro fundido de diámetro 0 60 m [1 und] | 4590.75h | 74,970.23 | 01.08.11 | 000000000001320 |  | 2737.46 | 2737.46 |  |
| 133 | 1.8.12 | Empalmes de tuberías DN 200 a 250 buzón existente en servicio | 10d | 2016-06-06 | 2016-06-16 | 127 | 14d | 0d | start no earlier than 2015-09-30 | MO: Capataz incluye leyes sociales [7.5%]; MO: Operador de maquinaria-equipo pesado [125%]; MO: Operario incluye leyes sociales [75%]; MO: Oficial incluye leyes sociales [75%]; MO: Peon incluye leyes sociales [800%]; Camión volquete 4x2 140 - 210 HP 6m3 [25%]; Compresora neumática 76 HP 125 - 175 pcm. [50%]; Martillo neumático 25 - 29 kg [50%]; Martillo cincel para corte-demolición [50%]; Arena gruesa [0.15 m3]; Piedra partida-grava de 1/2" - 3/4" [0.26 m3]; Agua incluye transporte a pie de obra (Camión cisterna y Motobomba) [0.83 m3]; Cemento portland I sector público; en bolsa [2.12 und] | 1006h | 18,728.99 | 01.08.12 | 000000000001241 |  | 489.33 | 1957.32 |  |
| 134 | 1.8.13 | Empalmes de tuberías DN 300 a 350 buzón existente en servicio | 10d | 2016-06-06 | 2016-06-16 | 133SS | 14d | 0d | start no earlier than 2015-09-30 | MO: Capataz incluye leyes sociales [3.1%]; MO: Operador de maquinaria-equipo pesado [43.8%]; MO: Operario incluye leyes sociales [31.2%]; MO: Oficial incluye leyes sociales [31.2%]; MO: Peon incluye leyes sociales [300%]; Camión volquete 4x2 140 - 210 HP 6m3 [6.2%]; Compresora neumática 87 HP 250 - 330 pcm. [18.8%]; Martillo neumático 25 - 29 kg [18.8%]; Martillo cincel para corte-demolición [18.8%]; Arena gruesa [0.08 m3]; Piedra partida-grava de 1/2" - 3/4" [0.14 m3]; Agua incluye transporte a pie de obra (Camión cisterna y Motobomba) [0.21 m3]; Cemento portland I sector público; en bolsa [1.13 und] | 377.5h | 6,875.25 | 01.08.13 | 000000000001242 |  | 726.24 | 726.24 |  |
| 135 | 1.8.14 | Pasamuro de polietileno para tubería de HDPE de DN 200 mm (Union de tub HDPE 200 a buzon) | 10d | 2016-06-06 | 2016-06-16 | 133SS | 14d |  | start no earlier than 2015-09-30 | Pasamuro de HDPE DN 200 mm [150 und] |  | 70,470 | 01.08.14 | 000000000001243 | 150 | 469.8 | 70470 |  |
| 136 | 1.8.15 | Pasamuro de polietileno para tubería de HDPE de DN 250 mm (Union de tub HDPE 250 a buzon) | 10d | 2016-06-06 | 2016-06-16 | 134SS | 14d |  | start no earlier than 2015-09-30 | Pasamuro de HDPE DN 250 mm [20 und] |  | 10,910 | 01.08.15 | 000000000001321 | 20 | 545.5 | 10910 |  |
| 137 | 1.9 | **CONEXIONES DOMICILIARIAS** | 76d | 2016-04-15 | 2016-06-30 |  | 0d |  |  |  | 57233.7h | 1,680,421.47 | 02 | 000000000001244 |  |  |  |  |
| 138 | 1.9.1 | **TRABAJOS PRELIMINARES Y COMPLEMENTARIOS** | 76d | 2016-04-15 | 2016-06-30 |  | 0d |  |  |  | 3232.77h | 88,961.75 | 02.01 | 000000000001245 |  |  |  |  |
| 139 | 1.9.1.1 | Trazo y replanteo inicial para conexión domiciliaria | 10d | 2016-04-15 | 2016-04-25 | 15 | 0d |  | start no earlier than 2015-09-30 | MO: Técnico incluye leyes sociales [67.3%]; MO: Capataz incluye leyes sociales [6.1%]; MO: Operario incluye leyes sociales [67.3%]; Pintura esmalte sintético envase por galón [7.76 und] | 112.52h | 2,949.61 | 02.01.01 | 000000000001246 | 485 | 2.52 | 1222.2 | 240 |
| 140 | 1.9.1.2 | Replanteo final de la obra para conexión domiciliaria | 10d | 2016-06-20 | 2016-06-30 | 157 | 0d |  | start no earlier than 2016-06-20 | MO: Técnico incluye leyes sociales [75.8%]; MO: Capataz incluye leyes sociales [7.6%]; MO: Dibujante incl. leyes sociales [75.8%]; MO: Operario incluye leyes sociales [75.8%]; Papel-copia xeros tamaño A4 [970 und] | 187.94h | 4,236.72 | 02.01.02 | 000000000001247 | 485 | 3.69 | 1789.65 | 160 |
| 141 | 1.9.1.3 | Proteccion de redes existentes de DN 100 a 150 | 52d | 2016-04-25 | 2016-06-16 | 139 | 14d | 0d | start no earlier than 2015-09-30 | MO: Capataz incluye leyes sociales [10%]; MO: Operario incluye leyes sociales; MO: Peon incluye leyes sociales; Alambre negro N° 8 [247.5 kg]; Clavo c/cabeza para madera (promedio) [2.25 kg]; Madera para encofrado y carpintería [149.85 p2] | 873.6h | 16,288.04 | 02.01.03 | 000000000001248 | 450 | 32.25 | 14512.5 | 10 |
| 142 | 1.9.1.4 | Cinta plástica señalizadora para límite de seguridad de obra-SEDAPAL | 52d | 2016-04-25 | 2016-06-16 | 141SS | 14d |  | start no earlier than 2015-09-30 | MO: Capataz incluye leyes sociales [9.3%]; MO: Operario incluye leyes sociales [9.3%]; MO: Peon incluye leyes sociales [91.6%]; Cinta plástica para señal de seguridad de obra [63378%]; Arena gruesa [3.02 m3]; Piedra partida-grava de 1/2" - 3/4" [3.02 m3]; Madera para encofrado y carpintería [54.32 p2]; Cemento portland I sector público; en bolsa [6.04 und] | 457.97h | 7,969.09 | 02.01.04 | 000000000001249 | 3018 | 0.73 | 2203.14 | 300 |
| 143 | 1.9.1.5 | Riego de zona de trabajo para mitigar la contaminación -polvo (con autorización de uso de grifo) | 52d | 2016-04-25 | 2016-06-16 | 141SS | 14d |  | start no earlier than 2015-09-30 | MO: Capataz incluye leyes sociales [7.5%]; MO: Operador de maquinaria-equipo pesado [75.4%]; MO: Peon incluye leyes sociales [150.9%]; Camión cisterna 4x2 (agua) 122HP 1500gal [75.4%]; Motobomba 5 HP de 2" incluye manguera [75.4%] | 1600.75h | 57,518.3 | 02.01.05 | 000000000001250 | 1509 | 1.46 | 2203.14 | 1000 |

| ID | WBS | Task | Duration | Start | Finish | Predecessors | Total slack | Free slack | Constraint | Resources | Work | Cost | Text1 | Text8 | Text2 | Text3 | Text4 | Text6 |
| --- | --- | --- | --- | --- | --- | --- | --- | --- | --- | --- | --- | --- | --- | --- | --- | --- | --- | --- |
| 144 | 1.9.2 | **DEMOLICIONES** | 53d | 2016-04-25 | 2016-06-17 |  | 13d |  |  |  | 12082.7h | 309,639.86 | 02.02 | 000000000001251 |  |  |  |  |
| 145 | 1.9.2.1 | Demolición de caja y tapa en mal estado, de conex. dom. desague (incl. acomodo del desmonte para su eliminación) | 45d | 2016-04-25 | 2016-06-09 | 139 | 15d | 0d | start no earlier than 2015-09-30 | MO: Capataz incluye leyes sociales [8.4%]; MO: Peon incluye leyes sociales [168.8%] | 637.88h | 9,584.53 | 02.02.01 | 000000000001252 | 27 | 16.1 | 434.7 | 16 |
| 146 | 1.9.2.2 | Eliminación de desmonte en terreno normal R=20 km con maquinaria (incluye pago por disposicion final material peligroso) | 48d | 2016-04-25 | 2016-06-12 | 145SS | 18d |  | start no earlier than 2015-09-30 | MO: Capataz incluye leyes sociales [0.2%]; MO: Operador de maquinaria-equipo pesado [13.5%]; MO: Peon incluye leyes sociales [3.4%]; Camión volquete 4x2 210 - 280 HP 8m3 [11.8%]; Cargador sob. llanta 80-95HP 1 5-1 75 Yd3 [1.7%]; Autorización de centro de acopio para disposición final de residuos solidos (Tuberias de concreto p/desague) [1 m3] | 117.29h | 10,372.34 | 02.02.02 | 000000000001253 | 4.86 | 68.79 | 334.32 | 288 |
| 147 | 1.9.2.3 | Desmontaje y retiro de tubería DN 100 - 150 mm por reemplazar | 51d | 2016-04-27 | 2016-06-17 | 152SS+1d | 13d |  | start no earlier than 2015-09-30 | MO: Capataz incluye leyes sociales [9.4%]; MO: Operador de maquinaria-equipo pesado [94.3%]; MO: Operario incluye leyes sociales [94.3%]; MO: Peon incluye leyes sociales [94.3%] | 1192.86h | 21,769.39 | 02.02.03 | 000000000001254 | 1509 | 4.61 | 6956.49 | 100 |
| 148 | 1.9.2.4 | Corte+rotura, ED y reposic. De pavimento flexible asfalto caliente de e= 2" (incl. Pago por disp. Final) | 45d | 2016-04-25 | 2016-06-09 | 139 | 21d |  | start no earlier than 2015-09-30 | MO: Capataz incluye leyes sociales [3.4%]; MO: Operador de maquinaria-equipo pesado [44.8%]; MO: Operario incluye leyes sociales [10.5%]; MO: Peon incluye leyes sociales [115.7%]; Camión volquete 4x2 140 - 210 HP 6m3 [7.9%]; Camión volquete 4x2 210 - 280 HP 8m3 [6.5%]; Camioneta pick-up 4x2 simple 1000 kg 90 HP [6.4%]; Cargador sob. llanta 80-95HP 1 5-1 75 Yd3 [1%]; Compactadora vibrat. de plancha 4 HP [1.4%]; Compactadora vibrat. de plancha 7 HP [5.5%]; Compresora neumática 76 HP 125 - 175 pcm. [1.8%]; Martillo neumático 21 - 24 kg [3.4%]; Martillo cincel para corte-demolición [3.4%]; Motoniveladora de 85 - 120 HP [1%]; Pavimentadora sobre oruga 69HP 10 pies [1.4%]; Rodillo neumático autoprop. 60-80 HP 3 - 5 ton [2.3%]; Rodillo tandem estático autopropulsado 30 - 57 HP 3 - 5 ton [1.4%]; Rodillo tandem vibratorio autopropulsado 15-35HP 2 5 - 4 ton [1%]; Cortadora de pavimento C35-35HP i/combus [13.5%]; Material granular S. A1a-A1b AASHTO [2.7 m3]; Asfalto caliente (en planta) [0.7 m3]; Agua incluye transporte a pie de obra (Camión cisterna y Motobomba) [2.24 m3]; Autorización de centro de acopio para disposición final de residuos solidos (Tuberias de concreto p/desague) [1 m3]; Autorizacion de centro de acopio para disposicion final de residuos peligrosos [1 m3]; Asfalto líquido RC 250 (galón) [1.19 und]; Kerosene para uso industrial envase por galón [0.86 und]; Disco para corte PC 300 de 18" [0.1%] | 835.49h | 25,122.46 | 02.02.04 | 000000000001255 | 10.8 | 97.54 | 1053.43 |  |
| 149 | 1.9.2.5 | Corte+rotura, ED y reposición de vereda rígida f'c 175 kg/cm2 de 10 cm espesor (incl. Pago por disp. Final) | 45d | 2016-04-25 | 2016-06-09 | 139 | 21d | 0d | start no earlier than 2015-09-30 | MO: Ingeniero residente incl. leyes sociales [0.6%]; MO: Técnico incluye leyes sociales [0.6%]; MO: Capataz incluye leyes sociales [9.6%]; MO: Operador de maquinaria-equipo pesado [126.5%]; MO: Operario incluye leyes sociales [88.2%]; MO: Oficial incluye leyes sociales [18.6%]; MO: Peon incluye leyes sociales [272%]; Camión volquete 4x2 210 - 280 HP 8m3 [9.4%]; Camioneta pick-up 4x2 simple 1000 kg 90 HP [15.4%]; Camión concretero 6x4 235-300HP 8m3 [21.2%]; Cargador sob. llanta 80-95HP 1 5-1 75 Yd3 [2.5%]; Compactadora vibrat. de plancha 7 HP [8.1%]; Compresora neumática 76 HP 125 - 175 pcm. [5.8%]; Planta-Dosificadora de concreto PM (planta) [0.6%]; Martillo neumático 21 - 24 kg [11.2%]; Martillo cincel para corte-demolición [11.2%]; Motoniveladora de 85 - 120 HP [2.5%]; Rodillo neumático autoprop. 60-80 HP 3 - 5 ton [2.5%]; Rodillo tandem vibratorio autopropulsado 15-35HP 2 5 - 4 ton [2.5%]; Cortadora de pavimento C35-35HP i/combus [45%]; Vibrador de concreto 4 HP 18PL [18%]; Arena gruesa [1.51 m3]; Material granular S. A1a-A1b AASHTO [3.38 m3]; Piedra partida-grava de 1/2" - 3/4" [2.09 m3]; Agua incluye transporte a pie de obra (Camión cisterna y Motobomba) [9.99 m3]; Agua incluye transporte a pie de obra (Camión cisterna y Motobomba) [0.6 m3]; Madera para encofrado y carpintería [13.31 p2]; Cemento portland I sector público; en bolsa [24.82 und]; Sika:plastiment HE98 balde de 20 kg [0.27 und]; Regla de madera tipo tornillo especial [0.27 und]; Disco para corte PC 300 de 18" [0.3%] | 2419.74h | 70,508.94 | 02.02.05 | 000000000001257 | 27 | 92.3 | 2492.1 |  |
| 150 | 1.9.2.6 | Corte+Rotura, ED y reposición de Piso Loseta corriente de 0,20 x 0,20 m (incl. Pago por disp. Final) | 45d | 2016-04-25 | 2016-06-09 | 149SS | 21d |  | start no earlier than 2015-09-30 | MO: Capataz incluye leyes sociales [35.6%]; MO: Operador de maquinaria-equipo pesado [222.3%]; MO: Operario incluye leyes sociales [509.1%]; MO: Oficial incluye leyes sociales [134.8%]; MO: Peon incluye leyes sociales [785.4%]; Camión volquete 4x2 210 - 280 HP 8m3 [58.5%]; Camioneta pick-up 4x2 simple 1000 kg 90 HP [8.6%]; Mezcladora concreto t/tambor23HP 11-12p3 [134.8%]; Cargador sob. llanta 80-95HP 1 5-1 75 Yd3 [11.7%]; Compactadora vibrat. de plancha 7 HP [0.3%]; Compresora neumática 76 HP 125 - 175 pcm. [0.7%]; Martillo neumático 21 - 24 kg [1.4%]; Martillo cincel para corte-demolición [1.4%]; Motoniveladora de 85 - 120 HP [0.3%]; Rodillo neumático autoprop. 60-80 HP 3 - 5 ton [0.3%]; Rodillo tandem vibratorio autopropulsado 15-35HP 2 5 - 4 ton [0.3%]; Cortadora de pavimento C35-35HP i/combus [5.6%]; Loseta corriente de 0 20 x 0 20 m [35.37 m2]; Arena fina [0.91 m3]; Arena gruesa [17.18 m3]; Piedra partida-grava de 1/2" - 3/4" [29.65 m3]; Agua incluye transporte a pie de obra (Camión cisterna y Motobomba) [1.27 m3]; Agua incluye transporte a pie de obra (Camión cisterna y Motobomba) [7.07 m3]; Cemento portland I sector público; en bolsa [8.83 und]; Cemento portland V sector público; en bolsa [238.53 und]; Disco para corte PC 300 de 18" [0%] | 6879.48h | 172,282.2 | 02.02.06 | 000000000001258 | 33.69 | 365.65 | 12318.75 |  |
| 151 | 1.9.3 | **MOVIMIENTOS DE TIERRAS** | 55d | 2016-04-26 | 2016-06-20 |  | 0d |  |  |  | 29512.3h | 706,973.78 | 02.03 | 000000000001259 |  |  |  |  |
| 152 | 1.9.3.1 | Excav. zanja (pulso) p/tub. terr-normal DN 100 - 150 de 0,60 m a 1,00 m prof. | 50d | 2016-04-26 | 2016-06-15 | 139FS+1d | 0d |  | start no earlier than 2015-09-30 | MO: Capataz incluye leyes sociales [10%]; MO: Peon incluye leyes sociales [996.7%] | 4026.91h | 58,513.16 | 02.03.01 | 000000000001260 | 1479 | 17.76 | 26267.04 | 67.45 |
| 153 | 1.9.3.2 | Excav. zanja (pulso) p/tub. terr-normal DN 100 - 150 de 1,01 m a 1,25 m prof. | 50d | 2016-04-26 | 2016-06-15 | 139FS+1d | 13d | 0d | start no earlier than 2015-09-30 | MO: Capataz incluye leyes sociales [6.2%]; MO: Peon incluye leyes sociales [619.7%] | 2503.65h | 36,377.78 | 02.03.02 | 000000000001261 | 30 | 24.74 | 742.2 | 48.41 |
| 154 | 1.9.3.3 | Refine y nivel de zanja terr-normal para tub. DN 100 - 150 para toda profund. | 50d | 2016-04-27 | 2016-06-16 | 152SS+1d | 14d |  | start no earlier than 2015-09-30 | MO: Capataz incluye leyes sociales [9%]; MO: Peon incluye leyes sociales [182.3%] | 765.4h | 11,495.41 | 02.03.03 | 000000000001265 | 1509 | 1.4 | 2112.6 | 183.91 |
| 155 | 1.9.3.4 | Relleno comp.zanja (máq) p/tub. t-normal DN 100 - 150 de 0,60 m a 1,00 m prof. | 50d | 2016-04-28 | 2016-06-17 | 152SS+2d | 0d |  | start no earlier than 2015-09-30 | MO: Capataz incluye leyes sociales [97.1%]; MO: Operador de maquinaria-equipo pesado [177.5%]; MO: Peon incluye leyes sociales [3844.1%]; Cargador sob. llanta 80-95HP 1 5-1 75 Yd3 [59.2%]; Compactadora vibrat. de plancha 7 HP [59.2%]; Rodillo liso vibrat. 0 8-1 1 ton manual ó de control remoto [59.2%]; Arena gruesa [94.36 m3]; Agua incluye transporte a pie de obra (Camión cisterna y Motobomba) [41.41 m3] | 17184.7h | 287,724.88 | 02.03.04 | 000000000001266 | 1479 | 11.09 | 16402.11 | 1251.76 |
| 156 | 1.9.3.5 | Relleno comp.zanja(pulso) p/tub t-normal DN 100 - 150 de 1,01 m a 1,25 m prof. | 50d | 2016-04-28 | 2016-06-17 | 153SS+2d | 13d | 0d | start no earlier than 2015-09-30 | MO: Capataz incluye leyes sociales [6.6%]; MO: Operador de maquinaria-equipo pesado [28.9%]; MO: Peon incluye leyes sociales [293.1%]; Compactadora vibrat. de plancha 7 HP [28.9%]; Arena gruesa [1.91 m3]; Agua incluye transporte a pie de obra (Camión cisterna y Motobomba) [1.05 m3] | 1429.89h | 21,556.35 | 02.03.05 | 000000000001267 | 30 | 17.94 | 538.2 | 103.9 |
| 157 | 1.9.3.6 | Elimin. desmonte(carg+v) t-normal D=20km p/tub. DN 100 - 150 para toda prof. | 51d | 2016-04-30 | 2016-06-20 | 155SS+2d | 0d |  | start no earlier than 2015-09-30 | MO: Capataz incluye leyes sociales [3.8%]; MO: Operador de maquinaria-equipo pesado [352.7%]; MO: Peon incluye leyes sociales [175.4%]; Camión volquete 4x2 210 - 280 HP 8m3 [307.5%]; Cargador sob. llanta 80-95HP 1 5-1 75 Yd3 [43.4%]; Autorización de centro de acopio para disposición final de residuos solidos (material desmonte no peligroso) [1 m3] | 3601.68h | 291,306.2 | 02.03.06 | 000000000001271 | 1509 | 10.28 | 15512.52 | 3428.57 |
| 158 | 1.9.4 | **SUMINISTRO E INSTAL. DE ELEMENTOS PARA CONEXION DOMICILIARIA** | 54d | 2016-04-25 | 2016-06-18 |  | 12d |  |  |  | 12405.9h | 574,846.08 | 02.04 | 000000000001272 |  |  |  |  |
| 159 | 1.9.4.1 | **TUBERIAS** | 52d | 2016-04-25 | 2016-06-16 |  | 14d |  |  |  | 7274.47h | 433,461.44 | 02.04.01 | 000000000001273 |  |  |  |  |
| 160 | 1.9.4.1.1 | Tubería PVC-U UF NTP ISO 4435 SN 2 DN 150 incl. anillo + 2% desperdicios | 20d | 2016-04-25 | 2016-05-15 | 139 | 46d | 0d | start no earlier than 2015-09-30 | Flete-transporte de tubería liviana no metálica (PVC HDPE GRP ó similar) [3505.41 kg]; Tubo de PVC UF norma ISO 4435 SN 2 DN 150 mm [153918%]; Anillo jebe p/tuber. PVC UF DN 150 mm [256.53 und]; Lubricante para tuberia de unión flexible; (galón) [1.51 und] |  | 24,711.52 | 02.04.01.01 | 000000000001274 | 1509 | 16.38 | 24717.42 |  |
| 161 | 1.9.4.1.2 | Instalación de tubería de PVC p/desagüe DN 150 incluye prueba hidráulica | 50d | 2016-04-27 | 2016-06-16 | 152SS+1d | 14d | 0d | start no earlier than 2015-09-30 | MO: Capataz incluye leyes sociales [39.6%]; MO: Operario incluye leyes sociales [349%]; MO: Oficial incluye leyes sociales [349%]; MO: Peon incluye leyes sociales [454%]; Agua incluye transporte a pie de obra (Camión cisterna y Motobomba) [79.98 m3]; Tapón de acero DN 150 mm [3.02 und] | 4765.93h | 80,938.4 | 02.04.01.02 | 000000000001275 | 1509 |  | 6036 | 720 |
| 162 | 1.9.4.1.3 | Abrazadera de polietileno para conexión domiciliaria de alcantarillado DN 200 mm x 160mm - incluye codo de 90 | 20d | 2016-04-25 | 2016-05-15 | 160SS | 46d | 0d | start no earlier than 2015-09-30 | Codo de PVC 90° DN 15 mm [1321 und]; Abrazadera de polietileno DN 200 x Salida 160mm para conex. alcantarillado s/especif. [1321 und] |  | 266,657.06 | 02.04.01.03 | 000000000001276 | 1321 | 201.86 | 266657.06 |  |
| 163 | 1.9.4.1.4 | Abrazadera de polietileno para conexión domiciliaria de alcantarillado DN 200 mm x 160mm - incluye codo de 90 | 20d | 2016-04-25 | 2016-05-15 | 162SS | 46d | 0d | start no earlier than 2015-09-30 | Codo de PVC 90° DN 15 mm [7 und]; Abrazadera de polietileno DN 200 x Salida 160mm para conex. alcantarillado s/especif. [7 und] |  | 1,413.02 | 02.04.01.04 | 000000000001277 |  | 201.86 | 1413.02 |  |
| 164 | 1.9.4.1.5 | Abrazadera de polietileno para conexión domiciliaria de alcantarillado DN 250 mm x 160mm - incluyen codo 45 | 20d | 2016-04-25 | 2016-05-15 | 163SS | 46d |  | start no earlier than 2015-09-30 | Codo de PVC UF 45° DN 150 mm [12 und]; Abrazadera de polietileno DN 250 x Salida 160mm para conex. alcantarillado s/especif. [12 und] |  | 3,176.88 | 02.04.01.05 | 000000000001278 | 12 | 264.74 | 3176.88 |  |
| 165 | 1.9.4.1.6 | Suministro de elemento de empotramiento de tubería de PVC-U DN 315 - incluye codo DNE 160 de 45 | 20d | 2016-04-25 | 2016-05-15 | 163SS | 46d |  | start no earlier than 2015-09-30 | Codo de PVC UF 45° DN 150 mm [12 und]; Abrazadera de polietileno DN 250 x Salida 160mm para conex. alcantarillado s/especif. [12 und] |  | 3,176.88 | 02.04.01.06 | 000000000001278 | 12 | 264.74 | 3176.88 |  |
| 166 | 1.9.4.1.7 | Suministro de elemento de empotramiento de tubería de PVC-U DN 315- incluye codo DNE 160 de 90 | 20d | 2016-04-25 | 2016-05-15 | 163SS | 46d |  | start no earlier than 2015-09-30 | Codo de PVC UF 45° DN 150 mm [12 und]; Abrazadera de polietileno DN 250 x Salida 160mm para conex. alcantarillado s/especif. [12 und] |  | 3,176.88 | 02.04.01.07 | 000000000001278 | 12 | 264.74 | 3176.88 |  |
| 167 | 1.9.4.1.8 | Instalación de abrazadera para red de HDPE DN 200 y salida a conexión domiciliaria de alcantarillado DN 160 | 50d | 2016-04-27 | 2016-06-16 | 161SS | 14d | 0d | start no earlier than 2015-09-30 | MO: Capataz incluye leyes sociales [10%]; MO: Operario incluye leyes sociales; MO: Oficial incluye leyes sociales; Flete accesorio de abrazadera DN 200 mm - 250 mm [1328 und] | 836.18h | 16,736.93 | 02.04.01.08 | 000000000001279 | 1328 | 7.94 | 10544.32 | 46 |
| 168 | 1.9.4.1.9 | Instalación de abrazadera para red de HDPE DN 250 y salida a conexión domiciliaria de alcantarillado DN 160 | 50d | 2016-04-27 | 2016-06-16 | 167SS | 14d | 0d | start no earlier than 2015-09-30 | MO: Capataz incluye leyes sociales [10%]; MO: Operario incluye leyes sociales; MO: Oficial incluye leyes sociales; Flete accesorio de abrazadera DN 200 mm - 250 mm [1328 und] | 836.18h | 16,736.93 | 02.04.01.09 | 000000000001279 | 1328 | 7.94 | 10544.32 | 46 |
| 169 | 1.9.4.1.10 | Instalación de elemento de empotramiento de tubería PVC-U DN 160 a 315 | 50d | 2016-04-27 | 2016-06-16 | 168SS | 14d |  | start no earlier than 2015-09-30 | MO: Capataz incluye leyes sociales [10%]; MO: Operario incluye leyes sociales; MO: Oficial incluye leyes sociales; Flete accesorio de abrazadera DN 200 mm - 250 mm [1328 und] | 836.18h | 16,736.93 | 02.04.01.10 | 000000000001279 | 1328 | 7.94 | 10544.32 | 46 |

| ID | WBS | Task | Duration | Start | Finish | Predecessors | Total slack | Free slack | Constraint | Resources | Work | Cost | Text1 | Text8 | Text2 | Text3 | Text4 | Text6 |
| --- | --- | --- | --- | --- | --- | --- | --- | --- | --- | --- | --- | --- | --- | --- | --- | --- | --- | --- |
| 170 | 1.9.4.2 | **CAJAS** | 51d | 2016-04-25 | 2016-06-15 |  | 15d |  |  |  | 3461.09h | 103,106.55 | 02.04.02 | 000000000001281 |  |  |  |  |
| 171 | 1.9.4.2.1 | Suministro de caja de concreto simple y tapa concreto armado de 0,30 m x 0,60 m (cajas a rehabilitar) | 20d | 2016-04-25 | 2016-05-15 | 160SS | 46d | 0d | start no earlier than 2015-09-30 | Caja de concreto 0 30 m x 0 60 m para desagüe (base intermedio y marco) [475 und]; Tapa concreto armado caja para desague de 0 30 m x 0 6 m [475 und] |  | 25,873.25 | 02.04.02.01 | 000000000001282 | 475 | 54.47 | 25873.25 |  |
| 172 | 1.9.4.2.2 | Sumin. caja concreto simple y tapa conc ar. 0,30 x 0,60m; de 1,01-1,25m prof.(incl. caja más 2 cuerpos adic. de 0,30m) | 20d | 2016-04-25 | 2016-05-15 | 171SS | 46d |  | start no earlier than 2015-09-30 | Caja de concreto 0 30 m x 0 60 m para desagüe (base intermedio y marco) [10 und]; Cuerpo intermedio de 0 30x0 30x0 60 m p/caja concreto -CD (adic. p/caja prof.) [20 und]; Tapa concreto armado caja para desague de 0 30 m x 0 6 m [10 und] |  | 984.7 | 02.04.02.02 | 000000000001283 | 10 | 98.47 | 984.7 |  |
| 173 | 1.9.4.2.3 | Instalación de caja y tapa de registro de 0,30 m x 0,60 m en terreno normal | 50d | 2016-04-26 | 2016-06-15 | 145SS+1d | 15d | 0d | start no earlier than 2015-09-30 | MO: Capataz incluye leyes sociales [9.9%]; MO: Operador de maquinaria-equipo pesado [24.7%]; MO: Operario incluye leyes sociales [99%]; MO: Oficial incluye leyes sociales [24.7%]; MO: Peon incluye leyes sociales [371.1%]; Camión volquete 4x2 140 - 210 HP 6m3 [24.7%]; Arena fina [0.95 m3]; Cemento portland I sector público; en bolsa [10.45 und] | 2216.67h | 48,906.08 | 02.04.02.03 | 000000000001287 | 475 | 100.21 | 47599.75 | 10 |
| 174 | 1.9.4.2.4 | Instalación caja y tapa de registro 0,30 m x 0,60 m, de 1.01-1,25m prof. en t-normal (incl. instalación de cuerpos adic) | 50d | 2016-04-26 | 2016-06-15 | 173SS | 15d |  | start no earlier than 2015-09-30 | MO: Capataz incluye leyes sociales [5.6%]; MO: Operador de maquinaria-equipo pesado [13.9%]; MO: Operario incluye leyes sociales [55.6%]; MO: Oficial incluye leyes sociales [13.9%]; MO: Peon incluye leyes sociales [208.3%]; Camión volquete 4x2 140 - 210 HP 6m3 [13.9%]; Arena fina [0.02 m3]; Cemento portland I sector público; en bolsa [0.25 und] | 1244.42h | 27,342.52 | 02.04.02.04 | 000000000001288 | 10 | 111.36 | 1113.6 |  |
| 175 | 1.9.4.3 | **PRUEBAS** | 50d | 2016-04-29 | 2016-06-18 |  | 12d |  |  |  | 1670.32h | 38,278.09 | 02.04.03 | 000000000001292 |  |  |  |  |
| 176 | 1.9.4.3.1 | Prueba hidráulica de tubería p/desague DN 150 | 50d | 2016-04-29 | 2016-06-18 | 161SS+2d | 12d | 0d | start no earlier than 2015-09-30 | MO: Capataz incluye leyes sociales [9.2%]; MO: Operario incluye leyes sociales [93.1%]; MO: Oficial incluye leyes sociales [93.1%]; MO: Peon incluye leyes sociales [93.1%]; Agua incluye transporte a pie de obra (Camión cisterna y Motobomba) [79.98 m3]; Tapón de acero DN 150 mm [3.02 und] | 1153.55h | 20,659.21 | 02.04.03.01 | 000000000001293 | 1509 | 3.14 | 4738.26 | 180 |
| 177 | 1.9.4.3.2 | Prueba de compactacion de suelos (proctor modificado - densidad de campo) | 50d | 2016-04-29 | 2016-06-18 | 176SS | 12d |  | start no earlier than 2015-09-30 | MO: Operador de maquinaria-equipo pesado [64.6%]; Camioneta pick-up 4x2 simple 1000 kg 90 HP [64.6%]; Prueba: Control de compactación (densidad de campo) [31 und]; Prueba: proctor modificado de campo [1.55 und] | 516.77h | 17,618.89 | 02.04.03.02 | 000000000001294 | 31 | 72.12 | 2235.72 | 48 |
